# BASICO

Schedule from MS Project, 2014-11-04 to 2016-02-08, status date 2015-01-12.

## Calendars

- Estándar: Mon-Fri 09:00-13:00, 15:00-19:00; Sat-Sun off.
- CALENDARIO DE TRABAJO MONTERESERVA: Mon-Fri 09:00-13:00, 15:00-19:00; Sat-Sun off. Exceptions (off unless hours are given): 2014-11-01 to 2016-12-31 09:00-13:00, 15:00-19:00 (TRABAJO LOS SABADOS, recurring), 2014-11-17 (NOVIEMBRE 17 DEL 2014), 2014-12-08 (DICIEMBRE 08 DEL 2014), 2014-12-22 to 2015-01-04 (ULTIMA SEMANA DE DICEIMBRE DEL 2014, PRIMERA ENERO DEL 2015), 2015-01-12 (ENERO 12 DEL 2015), 2015-03-23 (MARZO 23 DEL 2015), 2015-03-30 to 2015-04-05 (SEMANA SANTA 2015), 2015-05-01 (MAYO 01 DEL 2015), 2015-05-18 (MAYO 18 DEL 2015), 2015-06-08 (JUNIO 08 DEL 2015), 2015-06-15 (JUNIO 15 DEL 2015), 2015-06-29 (JUNIO 29 DEL 2015), 2015-07-20 (JULIO 20 DEL 2015), 2015-08-07 (AGOSTO 07 DEL 2015), 2015-08-17 (AGOSTO17 DEL 2015), 2015-10-12 (OCTUBRE 12 DEL 2015), 2015-11-02 (NOVIEMBRE 02 DEL 2015), 2015-11-16 (NOVIEMBRE 16 DEL 2015), 2015-12-08 (DICIEMBRE 08 DEL 2015), 2015-12-21 to 2016-01-03 (DICIEMBRE 25 DEL 2015), 2016-01-11 (ENERO 11 DEL 2016).
- DIAS CALENDARIO: Mon-Fri 09:00-13:00, 15:00-19:00; Sat-Sun off.
- DIAS CALENDARIO 2: Mon-Fri 09:00-13:00, 15:00-19:00; Sat-Sun off. Exceptions (off unless hours are given): 2013-08-01 to 2015-01-31 09:00-13:00, 15:00-19:00 (DIAS CALENDARIO).

## Schedule

| ID | WBS | Task | Duration | Start | Finish | Predecessors | Total slack | Free slack | Constraint | Calendar | Text1 | Text2 |
| --- | --- | --- | --- | --- | --- | --- | --- | --- | --- | --- | --- | --- |
| 1 | 1 | **MONTERESERVA TORRE 8** | 355d | 2014-11-04 | 2016-02-08 |  | 0d |  |  | DIAS CALENDARIO 2 | 3% |  |
| 2 | 1.1 | **PRELIMINARES DE OBRA** | 86d | 2014-11-04 | 2015-01-28 |  | 24d |  |  | DIAS CALENDARIO 2 | 100% | 84% |
| 3 | 1.1.1 | CONTRATACION EXCAVACION MECANICA | 6d | 2014-11-04 | 2014-11-10 |  | 20d | 0d | start no earlier than 2014-11-04 | CALENDARIO DE TRABAJO MONTERESERVA |  |  |
| 4 | 1.1.2 | BANCO DE HIERRO | 6d | 2014-11-10 | 2014-11-15 |  | 338d |  |  | CALENDARIO DE TRABAJO MONTERESERVA | 100% | 100% |
| 5 | 1.1.3 | LOCALIZACION DE OBRA | 6d | 2014-11-10 | 2014-11-15 |  | 21d | 2d |  | CALENDARIO DE TRABAJO MONTERESERVA | 100% | 100% |
| 6 | 1.1.4 | PEDIDO DE HIERRO ARRANQUE DE COLUMNAS | 2d | 2015-01-13 | 2015-01-14 |  | 0d |  | start no earlier than 2015-01-13 | CALENDARIO DE TRABAJO MONTERESERVA |  |  |
| 7 | 1.1.5 | LLEGADA ACERO A OBRA | 6d | 2015-01-15 | 2015-01-21 | 6 | 0d |  |  | CALENDARIO DE TRABAJO MONTERESERVA |  |  |
| 8 | 1.1.6 | FIGURACION ACERO COLUMNAS Y ZAPATAS | 6d | 2015-01-22 | 2015-01-28 | 7 | 290d |  |  | CALENDARIO DE TRABAJO MONTERESERVA |  |  |
| 9 | 1.2 | **ESTRUCTURAS** | 192d | 2014-11-11 | 2015-07-04 |  | 24d |  |  | DIAS CALENDARIO 2 | 7% | 2% |
| 10 | 1.2.1 | **ESTRUCTURA** | 180d | 2014-11-11 | 2015-06-17 |  | 24d |  |  | DIAS CALENDARIO 2 | 9% | 2% |
| 11 | 1.2.1.1 | **ESTRUCTURAS HASTA NIVEL - 3.80 SOTANO 2. ( 101 Y 102)** | 117d | 2014-11-11 | 2015-03-20 |  | 24d |  |  | DIAS CALENDARIO 2 | 29% | 7% |
| 12 | 1.2.1.1.1 | **-14.90** | 87d | 2014-11-11 | 2015-02-06 |  | 0d |  |  | DIAS CALENDARIO 2 |  |  |
| 13 | 1.2.1.1.1.1 | EXCAVACION MECANICA 1- NIVEL -14.90 | 6d | 2014-11-11 | 2014-11-18 | 3 | 20d | 0d | start no earlier than 2014-01-13 | CALENDARIO DE TRABAJO MONTERESERVA |  |  |
| 14 | 1.2.1.1.1.2 | EXCAVACION CAISSONS Y ZAPATAS ( 3 CAISSONS ) | 7d | 2014-11-19 | 2014-11-26 | 5, 13 | 20d | 0d |  | CALENDARIO DE TRABAJO MONTERESERVA | 59% | 18% |
| 15 | 1.2.1.1.1.3 | FUNDICION CAISSONS Y ZAPATAS ( 3 CAISSONS ) | 10d | 2014-11-20 | 2014-12-01 | 14FF+4d | 26d | 0d |  | CALENDARIO DE TRABAJO MONTERESERVA |  |  |
| 16 | 1.2.1.1.1.4 | VIGAS DE CIIMENTACION NIVEL -14.90 | 4d | 2015-01-22 | 2015-01-26 | 15FF+3d, 7 | 0d |  |  | CALENDARIO DE TRABAJO MONTERESERVA |  |  |
| 17 | 1.2.1.1.1.5 | COLUMNAS -14.90 A -11.90 ( 10 COLUMNAS ) | 4d | 2015-01-27 | 2015-01-30 | 16 | 0d |  |  | CALENDARIO DE TRABAJO MONTERESERVA |  |  |
| 18 | 1.2.1.1.1.6 | MURO DE CONTENCION M4 - MC2 | 10d | 2015-01-27 | 2015-02-06 | 17SS | 0d |  |  | CALENDARIO DE TRABAJO MONTERESERVA |  |  |
| 19 | 1.2.1.1.2 | **-11.90** | 76d | 2014-12-01 | 2015-02-19 |  | 0d |  |  | DIAS CALENDARIO 2 |  |  |
| 20 | 1.2.1.1.2.1 | EXCAVACION MECANICA 2- NIVEL -10.80 | 3d | 2014-12-01 | 2014-12-03 | 15FS-1d | 26d |  |  | CALENDARIO DE TRABAJO MONTERESERVA |  |  |
| 21 | 1.2.1.1.2.2 | EXCAVACION CAISSONS Y ZAPATAS ( 7 CAISSONS Y ZAPATA CENTRAL. ) | 12d | 2015-01-05 | 2015-01-19 | 20FF, 14 | 0d |  | must finish on 2015-01-19 | CALENDARIO DE TRABAJO MONTERESERVA | 59% | 18% |
| 22 | 1.2.1.1.2.3 | FUNDICION CAISSONS Y ZAPATA CENTRAL | 6d | 2015-01-14 | 2015-01-20 | 21FF+1d | 1d | 0d |  | CALENDARIO DE TRABAJO MONTERESERVA |  |  |
| 23 | 1.2.1.1.2.4 | VIGAS DE CIIMENTACION Y AEREAS NIVEL -11.90 | 6d | 2015-02-04 | 2015-02-10 | 22FF+3d, 16, 17FF+3d, 18FF+3d | 0d |  |  | CALENDARIO DE TRABAJO MONTERESERVA |  |  |
| 24 | 1.2.1.1.2.5 | COLUMNAS -11.90 A - 7.85 ( 16 COLUMNAS ) | 6d | 2015-02-11 | 2015-02-17 | 23, 17FF+3d, 18FF+3d | 0d |  |  | CALENDARIO DE TRABAJO MONTERESERVA |  |  |
| 25 | 1.2.1.1.2.6 | MUROS DE CONTENCION MC3 | 8d | 2015-02-11 | 2015-02-19 | 24SS | 0d |  |  | CALENDARIO DE TRABAJO MONTERESERVA |  |  |

| ID | WBS | Task | Duration | Start | Finish | Predecessors | Total slack | Free slack | Constraint | Calendar | Text1 | Text2 |
| --- | --- | --- | --- | --- | --- | --- | --- | --- | --- | --- | --- | --- |
| 26 | 1.2.1.1.3 | **-7.85** | 37d | 2015-01-20 | 2015-03-06 |  | 0d |  |  | DIAS CALENDARIO 2 |  |  |
| 27 | 1.2.1.1.3.1 | EXCAVACION MECANICA 3 - NIVEL -7.30 | 6d | 2015-01-20 | 2015-01-26 | 22FS-1d | 1d | 0d | start no earlier than 2015-01-05 | CALENDARIO DE TRABAJO MONTERESERVA |  |  |
| 28 | 1.2.1.1.3.2 | EXCAVACION CAISSONS Y ZAPATAS ( 4 CAISSONS Y 2 ZAPATAS ) | 8d | 2015-01-27 | 2015-02-04 | 27, 21 | 1d | 0d |  | CALENDARIO DE TRABAJO MONTERESERVA | 59% | 18% |
| 29 | 1.2.1.1.3.3 | FUNDICION CAISSONS Y ZAPATAS | 8d | 2015-01-28 | 2015-02-05 | 28FF+1d | 1d |  |  | CALENDARIO DE TRABAJO MONTERESERVA |  |  |
| 30 | 1.2.1.1.3.4 | VIGAS DE CIIMENTACION Y AEREAS NIVEL -7.85 | 12d | 2015-02-07 | 2015-02-20 | 29, 25FF+1d, 24FF+1d, 7 | 0d |  |  | CALENDARIO DE TRABAJO MONTERESERVA |  |  |
| 31 | 1.2.1.1.3.5 | COLUMNAS -7.85 A - 3.80 ( 17 COLUMNAS ) | 9d | 2015-02-21 | 2015-03-03 | 30, 24FF+3d, 25FF+3d | 0d |  |  | CALENDARIO DE TRABAJO MONTERESERVA |  |  |
| 32 | 1.2.1.1.3.6 | MURO DE CONTENCION MC 1 EJE 1 | 12d | 2015-02-21 | 2015-03-06 | 31SS | 0d |  |  | CALENDARIO DE TRABAJO MONTERESERVA |  |  |
| 33 | 1.2.1.1.4 | **-PLACA -3.80 ( PISO SOTANO 2)** | 20d | 2015-02-21 | 2015-03-20 |  | 6d |  |  | DIAS CALENDARIO 2 |  |  |
| 34 | 1.2.1.1.4.1 | EXCAVACION MECANICA 3 - PARA NIVEL -3.80 | 3d | 2015-02-21 | 2015-02-24 | 29FS-1d, 30 | 267d |  |  | CALENDARIO DE TRABAJO MONTERESERVA |  |  |
| 35 | 1.2.1.1.4.2 | COMPLEMENTOS VIGAS DE CIIMENTACION -7.85 | 4d | 2015-02-21 | 2015-02-25 | 30 | 8d | 7d |  | CALENDARIO DE TRABAJO MONTERESERVA |  |  |
| 36 | 1.2.1.1.4.3 | PLACA NIVEL -3.80 ( INCLUYE SENCILLAS Y DOBLES ALTURAS) | 12d | 2015-03-07 | 2015-03-20 | 31, 32, 35 | 0d |  |  | CALENDARIO DE TRABAJO MONTERESERVA |  |  |
| 37 | 1.2.1.2 | **PANTALLAS COLUMNAS Y LOSA N -0.05 S1 ( 201 Y 202)** | 12d | 2015-03-21 | 2015-04-07 |  | 0d |  |  | DIAS CALENDARIO 2 | 0% | 0% |
| 38 | 1.2.1.2.1 | PANTALLAS Y COLUMNAS ( 18 ELEMENTOS) | 5d | 2015-03-21 | 2015-03-27 | 36 | 0d |  |  | CALENDARIO DE TRABAJO MONTERESERVA |  |  |
| 39 | 1.2.1.2.2 | LOSA NIVEL -0.05 ( 201 Y 202) | 8d | 2015-03-21 | 2015-04-07 | 38FF+3d | 0d |  |  | CALENDARIO DE TRABAJO MONTERESERVA | 0% | 0% |
| 40 | 1.2.1.3 | **PANTALLAS COLUMNAS Y LOSA N + 3.70 P3, 301 Y 302.** | 7d | 2015-04-08 | 2015-04-16 |  | 0d |  |  | DIAS CALENDARIO 2 | 0% | 0% |
| 41 | 1.2.1.3.1 | PANTALLAS Y COLUMNAS | 5d | 2015-04-08 | 2015-04-13 | 39 | 0d |  |  | CALENDARIO DE TRABAJO MONTERESERVA | 0% | 0% |
| 42 | 1.2.1.3.2 | LOSA NIVEL + 3.70 ( 301 Y 302 ) 360 M2 APROX. | 7d | 2015-04-09 | 2015-04-16 | 41FF+3d | 0d |  |  | CALENDARIO DE TRABAJO MONTERESERVA | 0% | 0% |
| 43 | 1.2.1.4 | **PANTALLAS COLUMNAS Y LOSA N + 7.45 ( PISO 4 ) 401 Y 402** | 6d | 2015-04-17 | 2015-04-25 |  | 0d |  |  | DIAS CALENDARIO 2 | 0% | 0% |
| 44 | 1.2.1.4.1 | PANTALLAS Y COLUMNAS | 5d | 2015-04-17 | 2015-04-22 | 42 | 0d |  |  | CALENDARIO DE TRABAJO MONTERESERVA | 0% | 0% |
| 45 | 1.2.1.4.2 | LOSA NIVEL + 7.45 ( 401 Y 402 ) 360 M2 APROX. | 7d | 2015-04-18 | 2015-04-25 | 44FF+3d | 0d |  |  | CALENDARIO DE TRABAJO MONTERESERVA | 0% | 0% |
| 46 | 1.2.1.5 | **PANTALLAS COLUMNAS Y LOSA N + 11.20 ( PISO 5 )501 Y 502** | 8d | 2015-04-27 | 2015-05-06 |  | 0d |  |  | DIAS CALENDARIO 2 | 0% | 0% |
| 47 | 1.2.1.5.1 | PANTALLAS Y COLUMNAS | 5d | 2015-04-27 | 2015-05-02 | 45 | 0d |  |  | CALENDARIO DE TRABAJO MONTERESERVA | 0% | 0% |
| 48 | 1.2.1.5.2 | LOSA NIVEL+11.20 ( 501 Y 502 ) 360 M2 APROX. | 7d | 2015-04-28 | 2015-05-06 | 47FF+3d | 0d |  |  | CALENDARIO DE TRABAJO MONTERESERVA | 0% | 0% |
| 49 | 1.2.1.6 | **PANTALLAS COLUMNAS Y LOSA N + 14.95 ( PISO 6 ) BAJILLOS P6** | 7d | 2015-05-07 | 2015-05-15 |  | 0d |  |  | DIAS CALENDARIO 2 | 0% | 0% |
| 50 | 1.2.1.6.1 | PANTALLAS Y COLUMNAS | 5d | 2015-05-07 | 2015-05-12 | 48 | 0d |  |  | CALENDARIO DE TRABAJO MONTERESERVA | 0% | 0% |
| 51 | 1.2.1.6.2 | LOSA NIVEL + 14.95 ( BAJILLOS 601 Y 602 ) 360 M2 APROX. | 7d | 2015-05-08 | 2015-05-15 | 50FF+3d | 0d |  |  | CALENDARIO DE TRABAJO MONTERESERVA | 0% | 0% |

| ID | WBS | Task | Duration | Start | Finish | Predecessors | Total slack | Free slack | Calendar | Text1 | Text2 |
| --- | --- | --- | --- | --- | --- | --- | --- | --- | --- | --- | --- |
| 52 | 1.2.1.7 | **PANTALLAS COLUMNAS Y LOSA N + 18.70 ( PISO 6 ) ALTILLOS 601 Y 602** | 8d | 2015-05-16 | 2015-05-27 | 51 | 0d |  | DIAS CALENDARIO 2 | 0% | 0% |
| 53 | 1.2.1.7.1 | PANTALLAS Y COLUMNAS | 5d | 2015-05-16 | 2015-05-22 |  | 0d |  | CALENDARIO DE TRABAJO MONTERESERVA | 0% | 0% |
| 54 | 1.2.1.7.2 | LOSA NIVEL + 18.70 ( ALTILLOS 601 Y 602 ) 360 M2 APROX. | 7d | 2015-05-20 | 2015-05-27 | 53FF+4d | 0d |  | CALENDARIO DE TRABAJO MONTERESERVA | 0% | 0% |
| 55 | 1.2.1.8 | **PANTALLAS COLUMNAS Y CUBIERTA + 22.45** | 7d | 2015-05-28 | 2015-06-06 |  | 1d |  | DIAS CALENDARIO 2 | 0% | 0% |
| 56 | 1.2.1.8.1 | PANTALLAS Y COLUMNAS | 6d | 2015-05-28 | 2015-06-03 | 54 | 1d | 0d | CALENDARIO DE TRABAJO MONTERESERVA | 0% | 0% |
| 57 | 1.2.1.8.2 | LOSA CUBIERTA N+22.45 | 7d | 2015-05-30 | 2015-06-06 | 56FF+3d | 1d |  | CALENDARIO DE TRABAJO MONTERESERVA | 0% | 0% |
| 58 | 1.2.1.9 | **PANTALLAS COLUMNAS Y CUBIERTA ESCALERAS** | 7d | 2015-06-09 | 2015-06-17 |  | 12d |  | DIAS CALENDARIO 2 | 0% | 0% |
| 59 | 1.2.1.9.1 | PANTALLAS Y COLUMNAS | 4d | 2015-06-09 | 2015-06-12 | 57 | 14d | 0d | CALENDARIO DE TRABAJO MONTERESERVA | 0% | 0% |
| 60 | 1.2.1.9.2 | LOSA MAQUINAS | 7d | 2015-06-09 | 2015-06-17 | 59FF+3d | 14d | 0d | CALENDARIO DE TRABAJO MONTERESERVA | 0% | 0% |
| 61 | 1.2.2 | **DESCIMBRADA DE PLACAS** | 63d | 2015-04-08 | 2015-07-04 |  | 16d |  | DIAS CALENDARIO 2 | 0% | 0% |
| 62 | 1.2.2.1 | DESCIMBRADO NIVEL -3.80 | 6d | 2015-04-08 | 2015-04-14 | 39 | 47d | 28d | CALENDARIO DE TRABAJO MONTERESERVA | 0% | 0% |
| 63 | 1.2.2.2 | DESCIMBRADO NIVEL-0.05 | 6d | 2015-04-17 | 2015-04-23 | 42 | 17d | 0d | CALENDARIO DE TRABAJO MONTERESERVA | 0% | 0% |
| 64 | 1.2.2.3 | DESCIMBRADO NIVEL +3.70 | 6d | 2015-04-27 | 2015-05-04 | 45 | 9d | 0d | CALENDARIO DE TRABAJO MONTERESERVA | 0% | 0% |
| 65 | 1.2.2.4 | DESCIMBRADO NIVEL+7.45 | 6d | 2015-05-07 | 2015-05-13 | 48 | 2d | 0d | CALENDARIO DE TRABAJO MONTERESERVA | 0% | 0% |
| 66 | 1.2.2.5 | DESCIMBRADO NIVEL+11.20 | 6d | 2015-05-16 | 2015-05-23 | 51 | 3d | 0d | CALENDARIO DE TRABAJO MONTERESERVA | 0% | 0% |
| 67 | 1.2.2.6 | DESCIMBRADO NIVEL+14.95 | 6d | 2015-05-28 | 2015-06-03 | 54 | 0d |  | CALENDARIO DE TRABAJO MONTERESERVA | 0% | 0% |
| 68 | 1.2.2.7 | DESCIMBRADO NIVEL+18.70 | 6d | 2015-06-09 | 2015-06-16 | 57 | 1d | 0d | CALENDARIO DE TRABAJO MONTERESERVA | 0% | 0% |
| 69 | 1.2.2.8 | DESCIMBRADO NIVEL+ 22.45 | 6d | 2015-06-18 | 2015-06-24 | 68, 60 | 14d | 0d | CALENDARIO DE TRABAJO MONTERESERVA |  |  |
| 70 | 1.2.2.9 | DESCIMBRADO CUBIERTA ESCALERA | 2d | 2015-07-03 | 2015-07-04 | 57FS+12d, 69, 60FS+12d | 18d | 0d | CALENDARIO DE TRABAJO MONTERESERVA |  |  |
| 71 | 1.3 | **OBRA GRIS APARTAMENTOS** | 154d | 2015-04-24 | 2015-11-25 |  | 15d |  | DIAS CALENDARIO 2 | 0% | 0% |
| 72 | 1.3.1 | **PROLONGACIONES HIDRAULICAS** | 48d | 2015-04-24 | 2015-06-30 |  | 12d |  | DIAS CALENDARIO 2 | 0% | 0% |
| 73 | 1.3.1.1 | PROLONGACIONES HIDR. SOTANO | 4d | 2015-04-24 | 2015-04-28 | 63 | 17d | 8d | CALENDARIO DE TRABAJO MONTERESERVA | 0% | 0% |
| 74 | 1.3.1.2 | PROLONGACIONES HIDR. LOBBY | 4d | 2015-05-05 | 2015-05-08 | 63, 64 | 9d | 0d | CALENDARIO DE TRABAJO MONTERESERVA | 0% | 0% |
| 75 | 1.3.1.3 | PROLONGACIONES HIDR. P2 | 4d | 2015-05-14 | 2015-05-19 | 65 | 2d | 0d | CALENDARIO DE TRABAJO MONTERESERVA | 0% | 0% |
| 76 | 1.3.1.4 | PROLONGACIONES HIDR. P3 | 4d | 2015-05-25 | 2015-05-28 | 66 | 3d | 1d | CALENDARIO DE TRABAJO MONTERESERVA | 0% | 0% |
| 77 | 1.3.1.5 | PROLONGACIONES HIDR. P4 | 4d | 2015-06-04 | 2015-06-09 | 67 | 6d | 4d | CALENDARIO DE TRABAJO MONTERESERVA | 0% | 0% |
| 78 | 1.3.1.6 | PROLONGACIONES HIDR. P5 | 4d | 2015-06-17 | 2015-06-20 | 68 | 9d | 7d | CALENDARIO DE TRABAJO MONTERESERVA | 0% | 0% |
| 79 | 1.3.1.7 | PROLONGACIONES HIDR.P6 | 4d | 2015-06-25 | 2015-06-30 | 69 | 14d | 10d | CALENDARIO DE TRABAJO MONTERESERVA | 0% | 0% |

| ID | WBS | Task | Duration | Start | Finish | Predecessors | Total slack | Free slack | Calendar | Text1 | Text2 |
| --- | --- | --- | --- | --- | --- | --- | --- | --- | --- | --- | --- |
| 80 | 1.3.2 | **PROLONGACIONES ELECTRICAS** | 48d | 2015-04-24 | 2015-06-30 |  | 15d |  | DIAS CALENDARIO 2 | 0% | 0% |
| 81 | 1.3.2.1 | PROLONGACIONES ELECTR. SOTANO | 4d | 2015-04-24 | 2015-04-28 | 63 | 17d | 8d | CALENDARIO DE TRABAJO MONTERESERVA | 0% | 0% |
| 82 | 1.3.2.2 | PROLONGACIONES ELECT. LOBBY | 4d | 2015-05-05 | 2015-05-08 | 64 | 19d | 15d | CALENDARIO DE TRABAJO MONTERESERVA | 0% | 0% |
| 83 | 1.3.2.3 | PROLONGACIONES ELECT. P2 | 4d | 2015-05-14 | 2015-05-19 | 65 | 11d | 8d | CALENDARIO DE TRABAJO MONTERESERVA | 0% | 0% |
| 84 | 1.3.2.4 | PROLONGACIONES ELECT. P3 | 4d | 2015-05-25 | 2015-05-28 | 66 | 15d | 12d | CALENDARIO DE TRABAJO MONTERESERVA | 0% | 0% |
| 85 | 1.3.2.5 | PROLONGACIONES ELECT. P4 | 4d | 2015-06-04 | 2015-06-09 | 67 | 18d | 15d | CALENDARIO DE TRABAJO MONTERESERVA | 0% | 0% |
| 86 | 1.3.2.6 | PROLONGACIONES ELECT. P5 | 4d | 2015-06-17 | 2015-06-20 | 68 | 21d | 17d | CALENDARIO DE TRABAJO MONTERESERVA | 0% | 0% |
| 87 | 1.3.2.7 | PROLONGACIONES ELECT. P6 | 4d | 2015-06-25 | 2015-06-30 | 69 | 26d | 21d | CALENDARIO DE TRABAJO MONTERESERVA | 0% | 0% |
| 88 | 1.3.3 | **PROLONGACIONES ELECTRICAS AEREAS** | 55d | 2015-04-24 | 2015-07-09 |  | 15d |  | DIAS CALENDARIO 2 | 0% | 0% |
| 89 | 1.3.3.1 | PROLONGACIONES ELECTR.AEREAS SOTANO | 4d | 2015-04-24 | 2015-04-28 | 63 | 17d | 8d | CALENDARIO DE TRABAJO MONTERESERVA | 0% | 0% |
| 90 | 1.3.3.2 | PROLONGACIONES ELECT.AEREAS LOBBY | 4d | 2015-05-05 | 2015-05-08 | 64 | 19d | 15d | CALENDARIO DE TRABAJO MONTERESERVA | 0% | 0% |
| 91 | 1.3.3.3 | PROLONGACIONES ELECT.AEREAS P2 | 4d | 2015-05-14 | 2015-05-19 | 65 | 11d | 8d | CALENDARIO DE TRABAJO MONTERESERVA | 0% | 0% |
| 92 | 1.3.3.4 | PROLONGACIONES ELECT.AEREAS P3 | 4d | 2015-05-25 | 2015-05-28 | 66 | 15d | 12d | CALENDARIO DE TRABAJO MONTERESERVA | 0% | 0% |
| 93 | 1.3.3.5 | PROLONGACIONES ELECT.AEREAS P4 | 4d | 2015-06-17 | 2015-06-20 | 68 | 9d | 7d | CALENDARIO DE TRABAJO MONTERESERVA | 0% | 0% |
| 94 | 1.3.3.6 | PROLONGACIONES ELECT.AEREAS P5 | 4d | 2015-06-25 | 2015-06-30 | 69 | 14d | 10d | CALENDARIO DE TRABAJO MONTERESERVA | 0% | 0% |
| 95 | 1.3.3.7 | PROLONGACIONES ELECT.AEREAS P6 | 4d | 2015-07-06 | 2015-07-09 | 70 | 18d | 14d | CALENDARIO DE TRABAJO MONTERESERVA | 0% | 0% |
| 96 | 1.3.4 | **MAMPOSTERIA INTERNA** | 69d | 2015-05-09 | 2015-08-13 |  | 1d |  | DIAS CALENDARIO 2 | 0% | 0% |
| 97 | 1.3.4.1 | MAMPOSTERIA INTERNA. SOTANO Y APARTAMENTOS 101 Y 102 | 12d | 2015-05-09 | 2015-05-23 | 73, 81, 89, 74 | 9d | 0d | CALENDARIO DE TRABAJO MONTERESERVA | 0% | 0% |
| 98 | 1.3.4.2 | MAMPOSTERIA INTERNA. LOBBY Y APTOS 201 Y 202 | 9d | 2015-05-20 | 2015-05-29 | 82FF, 90FF, 75 | 2d | 0d | CALENDARIO DE TRABAJO MONTERESERVA | 0% | 0% |
| 99 | 1.3.4.3 | MAMPOSTERIA INTERNA. 301 Y 302 | 12d | 2015-05-30 | 2015-06-13 | 98, 75, 83, 91, 76 | 2d | 1d | CALENDARIO DE TRABAJO MONTERESERVA | 0% | 0% |
| 100 | 1.3.4.4 | MAMPOSTERIA INTERNA. 401 Y 402 | 12d | 2015-06-16 | 2015-06-30 | 99, 76, 84, 92, 77 | 2d | 0d | CALENDARIO DE TRABAJO MONTERESERVA | 0% | 0% |
| 101 | 1.3.4.5 | MAMPOSTERIA INTERNA. 501 Y 502 | 12d | 2015-07-01 | 2015-07-14 | 100, 77, 85, 93, 78 | 2d | 0d | CALENDARIO DE TRABAJO MONTERESERVA | 0% | 0% |
| 102 | 1.3.4.6 | MAMPOSTERIA INTERNA. BAJILLO 601 Y 602 | 12d | 2015-07-15 | 2015-07-29 | 101, 78, 86, 94, 79 | 2d | 0d | CALENDARIO DE TRABAJO MONTERESERVA | 0% | 0% |
| 103 | 1.3.4.7 | MAMPOSTERIA INTERNA. ALTILLOS 601 Y 602 | 12d | 2015-07-30 | 2015-08-13 | 102, 79, 87, 95, 80 | 2d | 0d | CALENDARIO DE TRABAJO MONTERESERVA | 0% | 0% |

| ID | WBS | Task | Duration | Start | Finish | Predecessors | Total slack | Free slack | Calendar | Text1 | Text2 |
| --- | --- | --- | --- | --- | --- | --- | --- | --- | --- | --- | --- |
| 104 | 1.3.5 | **ANCLAJES MAMPOSTERIA INTERNA Y DE FACHADA** | 65d | 2015-05-25 | 2015-08-21 |  | 14d |  | DIAS CALENDARIO 2 | 0% | 0% |
| 105 | 1.3.5.1 | ANCLAJES MAMPOSTERIA.SOTANO Y APARTAMENTOS 101 Y 102 | 6d | 2015-05-25 | 2015-05-30 | 62, 97 | 15d | 4d | CALENDARIO DE TRABAJO MONTERESERVA | 0% | 0% |
| 106 | 1.3.5.2 | ANCLAJES MAMPOSTERIA.LOBBY Y APTOS 201 Y 202 | 6d | 2015-05-30 | 2015-06-05 | 63, 98 | 10d | 6d | CALENDARIO DE TRABAJO MONTERESERVA | 0% | 0% |
| 107 | 1.3.5.3 | ANCLAJES MAMPOSTERIA. 301 Y 302 | 6d | 2015-06-16 | 2015-06-22 | 106, 64, 99 | 19d | 6d | CALENDARIO DE TRABAJO MONTERESERVA | 0% | 0% |
| 108 | 1.3.5.4 | ANCLAJES MAMPOSTERIA. 401 Y 402 | 6d | 2015-07-01 | 2015-07-07 | 107, 65, 100 | 16d | 5d | CALENDARIO DE TRABAJO MONTERESERVA | 0% | 0% |
| 109 | 1.3.5.5 | ANCLAJES MAMPOSTERIA. 501 Y 502 | 6d | 2015-07-15 | 2015-07-22 | 108, 66, 101 | 13d | 5d | CALENDARIO DE TRABAJO MONTERESERVA | 0% | 0% |
| 110 | 1.3.5.6 | ANCLAJES MAMPOSTERIA. BAJILLO 601 Y 602 | 6d | 2015-07-30 | 2015-08-05 | 109, 67, 102 | 10d | 6d | CALENDARIO DE TRABAJO MONTERESERVA | 0% | 0% |
| 111 | 1.3.5.7 | ANCLAJES MAMPOSTERIA ALTILLOS 601 Y 602 | 6d | 2015-08-14 | 2015-08-21 | 110, 68, 103 | 129d |  | CALENDARIO DE TRABAJO MONTERESERVA | 0% | 0% |
| 112 | 1.3.6 | **TRABAJOS CHIMENEA** | 37d | 2015-06-16 | 2015-08-05 |  | 133d |  | DIAS CALENDARIO 2 | 0% | 0% |
| 113 | 1.3.6.1 | TRABAJOS CHIMENEA. 301 Y 302 | 4d | 2015-06-16 | 2015-06-19 | 99 | 179d |  | CALENDARIO DE TRABAJO MONTERESERVA | 0% | 0% |
| 114 | 1.3.6.2 | TRABAJOS CHIMENEA. 401 Y 402 | 4d | 2015-07-01 | 2015-07-04 | 100 | 167d |  | CALENDARIO DE TRABAJO MONTERESERVA | 0% | 0% |
| 115 | 1.3.6.3 | TRABAJOS CHIMENEA. 501 Y 502 | 4d | 2015-07-15 | 2015-07-18 | 101 | 155d |  | CALENDARIO DE TRABAJO MONTERESERVA | 0% | 0% |
| 116 | 1.3.6.4 | TRABAJOS CHIMENEA 601 Y 602 | 6d | 2015-07-30 | 2015-08-05 | 102 | 141d |  | CALENDARIO DE TRABAJO MONTERESERVA | 0% | 0% |
| 117 | 1.3.7 | **PRUEBAS HIDRAULICAS** | 60d | 2015-05-25 | 2015-08-15 |  | 3d |  | DIAS CALENDARIO 2 | 0% | 0% |
| 118 | 1.3.7.1 | PRUEBAS HIDRAULICAS. SOTANO Y APARTAMENTOS 101 Y 102 | 2d | 2015-05-25 | 2015-05-26 | 97 | 19d | 7d | CALENDARIO DE TRABAJO MONTERESERVA | 0% | 0% |
| 119 | 1.3.7.2 | PRUEBAS HIDRAULICAS LOBBY Y APTOS 201 Y 202 | 2d | 2015-05-30 | 2015-06-01 | 98 | 14d | 10d | CALENDARIO DE TRABAJO MONTERESERVA | 0% | 0% |
| 120 | 1.3.7.3 | PRUEBAS HIDRAULICAS. 301 Y 302 | 2d | 2015-06-16 | 2015-06-17 | 119, 99 | 14d | 9d | CALENDARIO DE TRABAJO MONTERESERVA | 0% | 0% |
| 121 | 1.3.7.4 | PRUEBAS HIDRAULICAS.401 Y 402 | 2d | 2015-07-01 | 2015-07-02 | 120, 100 | 11d | 8d | CALENDARIO DE TRABAJO MONTERESERVA | 0% | 0% |
| 122 | 1.3.7.5 | PRUEBAS HIDRAULICAS. 501 Y 502 | 2d | 2015-07-15 | 2015-07-16 | 121, 101 | 8d | 6d | CALENDARIO DE TRABAJO MONTERESERVA | 0% | 0% |
| 123 | 1.3.7.6 | PRUEBAS HIDRAULICAS. 601 Y 602 BAJILLOS | 2d | 2015-07-30 | 2015-07-31 | 122, 102 | 5d | 3d | CALENDARIO DE TRABAJO MONTERESERVA | 0% | 0% |
| 124 | 1.3.7.7 | PRUEBAS HIDRAULICAS. 601 Y 602 ALTILLO | 2d | 2015-08-14 | 2015-08-15 | 123, 103 | 2d |  | CALENDARIO DE TRABAJO MONTERESERVA | 0% | 0% |
| 125 | 1.3.8 | **MAMPOSTERIA DE FACHADA** | 72d | 2015-05-25 | 2015-09-01 |  | 8d |  | DIAS CALENDARIO 2 | 0% | 0% |
| 126 | 1.3.8.1 | MAMPOSTERIA DE FACHADA ZONAS NO HABITABLES BAJO SOTANO | 12d | 2015-05-25 | 2015-06-06 | 127SF, 66 | 188d |  | CALENDARIO DE TRABAJO MONTERESERVA |  |  |
| 127 | 1.3.8.2 | MAMPOSTERIA DE FACHADA. SOTANO Y APTOS. 101 Y 102 | 10d | 2015-06-04 | 2015-06-17 | 89, 97, 67 | 0d |  | CALENDARIO DE TRABAJO MONTERESERVA | 0% | 0% |
| 128 | 1.3.8.3 | MAMPOSTERIA DE FACHADA. LOBBY Y APTOS. 201 Y 202 | 10d | 2015-06-18 | 2015-06-30 | 90, 98, 127, 68 | 0d |  | CALENDARIO DE TRABAJO MONTERESERVA | 0% | 0% |
| 129 | 1.3.8.4 | MAMPOSTERIA DE FACHADA. 301 Y 302 | 9d | 2015-07-01 | 2015-07-10 | 128, 91 | 0d |  | CALENDARIO DE TRABAJO MONTERESERVA | 0% | 0% |
| 130 | 1.3.8.5 | MAMPOSTERIA DE FACHADA. 401 Y 402 | 9d | 2015-07-11 | 2015-07-22 | 129, 92 | 0d |  | CALENDARIO DE TRABAJO MONTERESERVA | 0% | 0% |
| 131 | 1.3.8.6 | MAMPOSTERIA DE FACHADA. 501 Y 502 | 9d | 2015-07-23 | 2015-08-01 | 130, 93 | 0d |  | CALENDARIO DE TRABAJO MONTERESERVA | 0% | 0% |
| 132 | 1.3.8.7 | MAMPOSTERIA DE FACHADA. BAJILLOS 601 Y 602 | 9d | 2015-08-03 | 2015-08-13 | 131, 94 | 0d |  | CALENDARIO DE TRABAJO MONTERESERVA | 0% | 0% |
| 133 | 1.3.8.8 | MAMPOSTERIA DE FACHADA. ALTILLOS 601 Y 602 | 8d | 2015-08-14 | 2015-08-24 | 132, 95FF | 0d |  | CALENDARIO DE TRABAJO MONTERESERVA | 0% | 0% |
| 134 | 1.3.8.9 | MAMPOSTERIA DE FACHADA, ANTEPECHOS REMATE CUBIERTA. | 8d | 2015-08-24 | 2015-09-01 | 133FS-1d, 57FF+42d | 0d |  | CALENDARIO DE TRABAJO MONTERESERVA | 0% | 0% |

| ID | WBS | Task | Duration | Start | Finish | Predecessors | Total slack | Free slack | Calendar | Text1 | Text2 |
| --- | --- | --- | --- | --- | --- | --- | --- | --- | --- | --- | --- |
| 135 | 1.3.9 | **MARCOS EN PIEDRA FACHADA** | 55d | 2015-06-18 | 2015-09-02 |  | 0d |  | DIAS CALENDARIO 2 |  |  |
| 136 | 1.3.9.1 | MARCOS EN PIEDRA FACHADA APTOS. 101 Y 102 | 8d | 2015-06-18 | 2015-06-26 | 127, 97, 144SS+4d | 6d | 2d | CALENDARIO DE TRABAJO MONTERESERVA |  |  |
| 137 | 1.3.9.2 | MARCOS EN PIEDRA FACHADA APTOS. 201 Y 202 | 8d | 2015-07-01 | 2015-07-09 | 128, 136, 98, 145SS+4d | 4d | 1d | CALENDARIO DE TRABAJO MONTERESERVA |  |  |
| 138 | 1.3.9.3 | MARCOS EN PIEDRA FACHADA APTOS. 301 Y 302 | 8d | 2015-07-11 | 2015-07-21 | 129, 137, 99, 146SS+4d | 3d | 0d | CALENDARIO DE TRABAJO MONTERESERVA |  |  |
| 139 | 1.3.9.4 | MARCOS EN PIEDRA FACHADA APTOS. 401 Y 402 | 8d | 2015-07-23 | 2015-07-31 | 130, 138, 100, 147SS+4d | 2d | 0d | CALENDARIO DE TRABAJO MONTERESERVA |  |  |
| 140 | 1.3.9.5 | MARCOS EN PIEDRA FACHADA APTOS. 501 Y 502 | 8d | 2015-08-03 | 2015-08-12 | 131, 139, 101, 148SS+4d | 1d |  | CALENDARIO DE TRABAJO MONTERESERVA |  |  |
| 141 | 1.3.9.6 | MARCOS EN PIEDRA FACHADA APTOS. 601 Y 602 BAJILLOS | 8d | 2015-08-14 | 2015-08-24 | 132, 140, 102, 149SS+4d | 0d |  | CALENDARIO DE TRABAJO MONTERESERVA |  |  |
| 142 | 1.3.9.7 | MARCOS EN PIEDRA FACHADA APTOS. 601 Y 602 ALTILLOS | 8d | 2015-08-25 | 2015-09-02 | 133, 141, 103, 150SS+4d | 0d |  | CALENDARIO DE TRABAJO MONTERESERVA |  |  |
| 143 | 1.3.10 | **PAÑETES INTERNOS** | 61d | 2015-06-05 | 2015-08-28 |  | 0d |  | DIAS CALENDARIO 2 | 0% | 0% |
| 144 | 1.3.10.1 | PAÑETES SOTANO Y APTOS. 101 Y 102 | 12d | 2015-06-05 | 2015-06-20 | 127FF+3d, 105, 118, 97 | 11d | 0d | CALENDARIO DE TRABAJO MONTERESERVA |  |  |
| 145 | 1.3.10.2 | PAÑETES LOBBY Y APTOS. 201 Y 202 | 12d | 2015-06-19 | 2015-07-03 | 119, 128FF+3d, 106, 98 | 1d | 0d | CALENDARIO DE TRABAJO MONTERESERVA | 0% | 0% |
| 146 | 1.3.10.3 | PAÑETES. 301 Y 302 | 9d | 2015-07-04 | 2015-07-14 | 145, 120, 129FF+3d, 106, 99 | 1d | 0d | CALENDARIO DE TRABAJO MONTERESERVA | 0% | 0% |
| 147 | 1.3.10.4 | PAÑETES. 401 Y 402 | 9d | 2015-07-15 | 2015-07-25 | 146, 121, 130FF+3d, 107, 100 | 1d | 0d | CALENDARIO DE TRABAJO MONTERESERVA | 0% | 0% |
| 148 | 1.3.10.5 | PAÑETES. 501 Y 502 | 9d | 2015-07-27 | 2015-08-05 | 147, 122, 131FF+3d, 108, 101 | 1d | 0d | CALENDARIO DE TRABAJO MONTERESERVA | 0% | 0% |
| 149 | 1.3.10.6 | PAÑETES. BAJILLOS 601 Y 602 | 9d | 2015-08-06 | 2015-08-18 | 148, 123, 132FF+3d, 109, 102 | 1d | 0d | CALENDARIO DE TRABAJO MONTERESERVA | 0% | 0% |
| 150 | 1.3.10.7 | PAÑETES. ALTILLOS 601 Y 602 | 9d | 2015-08-19 | 2015-08-28 | 149, 124, 133FF+3d, 110, 103 | 1d | 0d | CALENDARIO DE TRABAJO MONTERESERVA | 0% | 0% |
| 151 | 1.3.11 | **AFINADOS INTERNOS** | 55d | 2015-06-22 | 2015-09-04 |  | 52d |  | DIAS CALENDARIO 2 | 0% | 0% |
| 152 | 1.3.11.1 | AFINADOS SOTANO Y APTOS. 101 Y 102 | 6d | 2015-06-22 | 2015-06-27 | 144, 118 | 58d | 50d | CALENDARIO DE TRABAJO MONTERESERVA |  |  |
| 153 | 1.3.11.2 | AFINADOS LOBBY Y APTOS. 201 Y 202 | 6d | 2015-07-04 | 2015-07-10 | 145, 119 | 90d | 2d | CALENDARIO DE TRABAJO MONTERESERVA | 0% | 0% |
| 154 | 1.3.11.3 | AFINADOS. 301 Y 302 | 6d | 2015-07-15 | 2015-07-22 | 153, 146, 120 | 87d | 2d | CALENDARIO DE TRABAJO MONTERESERVA | 0% | 0% |
| 155 | 1.3.11.4 | AFINADOS. 401 Y 402 | 6d | 2015-07-27 | 2015-08-01 | 154, 147, 121 | 84d | 3d | CALENDARIO DE TRABAJO MONTERESERVA | 0% | 0% |
| 156 | 1.3.11.5 | AFINADOS. 501 Y 502 | 6d | 2015-08-06 | 2015-08-13 | 155, 148, 122 | 81d | 3d | CALENDARIO DE TRABAJO MONTERESERVA | 0% | 0% |
| 157 | 1.3.11.6 | AFINADOS. BAJILLOS 601 Y 602 | 6d | 2015-08-19 | 2015-08-25 | 156, 149, 123 | 78d | 3d | CALENDARIO DE TRABAJO MONTERESERVA | 0% | 0% |
| 158 | 1.3.11.7 | AFINADOS. ALTILLOS 601 Y 602 | 6d | 2015-08-29 | 2015-09-04 | 157, 150, 124 | 75d | 47d | CALENDARIO DE TRABAJO MONTERESERVA | 0% | 0% |

| ID | WBS | Task | Duration | Start | Finish | Predecessors | Total slack | Free slack | Calendar | Text1 | Text2 |
| --- | --- | --- | --- | --- | --- | --- | --- | --- | --- | --- | --- |
| 159 | 1.3.12 | **TERRAZAS ( AFINADO, IMPERMEABILIACION,AFINADO, ACABADO,)** | 53d | 2015-07-15 | 2015-09-25 |  | 40d |  | DIAS CALENDARIO 2 | 0% | 0% |
| 160 | 1.3.12.1 | TERRAZAS LOBBY | 18d | 2015-07-15 | 2015-08-05 | 146 | 81d | 0d | CALENDARIO DE TRABAJO MONTERESERVA | 0% | 0% |
| 161 | 1.3.12.2 | TERRAZAS. P2 | 18d | 2015-07-27 | 2015-08-18 | 147 | 71d | 0d | CALENDARIO DE TRABAJO MONTERESERVA | 0% | 0% |
| 162 | 1.3.12.3 | TERRAZAS. P3 | 18d | 2015-08-06 | 2015-08-28 | 148 | 64d | 0d | CALENDARIO DE TRABAJO MONTERESERVA | 0% | 0% |
| 163 | 1.3.12.4 | TERRAZAS. P4 | 18d | 2015-08-19 | 2015-09-08 | 149 | 57d | 0d | CALENDARIO DE TRABAJO MONTERESERVA | 0% | 0% |
| 164 | 1.3.12.5 | TERRAZAS. P5 | 18d | 2015-08-29 | 2015-09-18 | 150 | 50d | 0d | CALENDARIO DE TRABAJO MONTERESERVA | 0% | 0% |
| 165 | 1.3.12.6 | TERRAZAS. P6 | 24d | 2015-08-29 | 2015-09-25 | 150 | 46d | 0d | CALENDARIO DE TRABAJO MONTERESERVA | 0% | 0% |
| 166 | 1.3.13 | **CIELOS DRY WALL TERRAZAS** | 47d | 2015-08-06 | 2015-10-09 |  | 71d |  | DIAS CALENDARIO 2 | 0% | 0% |
| 167 | 1.3.13.1 | CIELOS DRY WALL TERRAZAS LOBBY | 12d | 2015-08-06 | 2015-08-21 | 160 | 81d | 44d | CALENDARIO DE TRABAJO MONTERESERVA | 0% | 0% |
| 168 | 1.3.13.2 | CIELOS DRY WALL TERRAZAS. P2 | 12d | 2015-08-19 | 2015-09-01 | 161 | 78d | 42d | CALENDARIO DE TRABAJO MONTERESERVA | 0% | 0% |
| 169 | 1.3.13.3 | CIELOS DRY WALL TERRAZAS. P3 | 12d | 2015-08-29 | 2015-09-11 | 162 | 75d | 40d | CALENDARIO DE TRABAJO MONTERESERVA | 0% | 0% |
| 170 | 1.3.13.4 | CIELOS DRY WALL TERRAZAS. P4 | 12d | 2015-09-09 | 2015-09-22 | 163 | 71d | 37d | CALENDARIO DE TRABAJO MONTERESERVA | 0% | 0% |
| 171 | 1.3.13.5 | CIELOS DRY WALL TERRAZAS. P5 | 12d | 2015-09-19 | 2015-10-02 | 164 | 67d | 34d | CALENDARIO DE TRABAJO MONTERESERVA | 0% | 0% |
| 172 | 1.3.13.6 | CIELOS DRY WALL TERRAZAS. P5 | 12d | 2015-09-26 | 2015-10-09 | 165 | 87d |  | CALENDARIO DE TRABAJO MONTERESERVA | 0% | 0% |
| 173 | 1.3.14 | **TRATAMIENTO DE FACHADA** | 25d | 2015-08-27 | 2015-09-30 |  | 0d |  | DIAS CALENDARIO 2 | 0% | 0% |
| 174 | 1.3.14.1 | LAVADO DE FACHADA | 24d | 2015-08-27 | 2015-09-23 | 142FF+18d, 133 | 0d |  | CALENDARIO DE TRABAJO MONTERESERVA | 0% | 0% |
| 175 | 1.3.14.2 | IMPERMEABILIZACION FACHADA | 6d | 2015-09-24 | 2015-09-30 | 174 | 29d | 0d | CALENDARIO DE TRABAJO MONTERESERVA | 0% | 0% |
| 176 | 1.3.15 | **BARANDAS EN VIDRIO Y ACERO TERRAZAS** | 40d | 2015-10-01 | 2015-11-25 |  | 26d |  | DIAS CALENDARIO 2 | 0% | 0% |
| 177 | 1.3.15.1 | BARANDAS EN VIDRIO Y ACERO TERRAZAS SOTANO | 12d | 2015-10-01 | 2015-10-15 | 175 | 29d | 0d | CALENDARIO DE TRABAJO MONTERESERVA | 0% | 0% |
| 178 | 1.3.15.2 | BARANDAS EN VIDRIO Y ACERO TERRAZAS LOBBY | 6d | 2015-10-16 | 2015-10-22 | 177 | 29d | 0d | CALENDARIO DE TRABAJO MONTERESERVA | 0% | 0% |
| 179 | 1.3.15.3 | BARANDAS EN VIDRIO Y ACERO TERRAZAS P2 | 6d | 2015-10-23 | 2015-10-29 | 178, 160, 167 | 29d | 0d | CALENDARIO DE TRABAJO MONTERESERVA | 0% | 0% |
| 180 | 1.3.15.4 | BARANDAS EN VIDRIO Y ACERO TERRAZAS. P3 | 6d | 2015-10-30 | 2015-11-06 | 179, 161, 168 | 29d | 0d | CALENDARIO DE TRABAJO MONTERESERVA | 0% | 0% |
| 181 | 1.3.15.5 | BARANDAS EN VIDRIO Y ACERO TERRAZAS P4 | 5d | 2015-11-07 | 2015-11-12 | 180, 162, 169 | 29d | 0d | CALENDARIO DE TRABAJO MONTERESERVA | 0% | 0% |
| 182 | 1.3.15.6 | BARANDAS EN VIDRIO Y ACERO TERRAZAS P5 | 5d | 2015-11-13 | 2015-11-19 | 181, 163, 170 | 29d | 0d | CALENDARIO DE TRABAJO MONTERESERVA | 0% | 0% |
| 183 | 1.3.15.7 | BARANDAS EN VIDRIO Y ACERO TERRAZAS P6 | 5d | 2015-11-20 | 2015-11-25 | 182, 164, 171 | 29d | 32d | CALENDARIO DE TRABAJO MONTERESERVA | 0% | 0% |

| ID | WBS | Task | Duration | Start | Finish | Predecessors | Total slack | Free slack | Calendar | Text1 | Text2 |
| --- | --- | --- | --- | --- | --- | --- | --- | --- | --- | --- | --- |
| 184 | 1.3.16 | **VENTANERIA** | 81d | 2015-07-22 | 2015-11-11 |  | 3d |  | DIAS CALENDARIO 2 | 0% | 0% |
| 185 | 1.3.16.1 | ACTA DE VANOS | 8d | 2015-07-22 | 2015-07-30 | 138 | 3d | 2d | CALENDARIO DE TRABAJO MONTERESERVA | 0% | 0% |
| 186 | 1.3.16.2 | VENTANERIA SOTANO APTOS. 101 Y 102 | 5d | 2015-09-24 | 2015-09-29 | 185FS+42d, 174 | 0d |  | CALENDARIO DE TRABAJO MONTERESERVA | 0% | 0% |
| 187 | 1.3.16.3 | VENTANERIA. LOBBY APTOS 201 Y 202 | 5d | 2015-09-30 | 2015-10-05 | 186 | 5d | 0d | CALENDARIO DE TRABAJO MONTERESERVA | 0% | 0% |
| 188 | 1.3.16.4 | VENTANERIA APTOS. 301 Y 302 | 6d | 2015-10-06 | 2015-10-13 | 185FS+42d, 174, 187 | 7d | 0d | CALENDARIO DE TRABAJO MONTERESERVA | 0% | 0% |
| 189 | 1.3.16.5 | VENTANERIA APTOS 401 Y 402 | 6d | 2015-10-14 | 2015-10-20 | 188 | 9d | 0d | CALENDARIO DE TRABAJO MONTERESERVA | 0% | 0% |
| 190 | 1.3.16.6 | VENTANERIA APTOS 501 Y 502 | 6d | 2015-10-21 | 2015-10-27 | 189 | 11d | 0d | CALENDARIO DE TRABAJO MONTERESERVA | 0% | 0% |
| 191 | 1.3.16.7 | VENTANERIA APTOS 601 Y 602 BAJILLOS | 6d | 2015-10-28 | 2015-11-04 | 190 | 13d | 0d | CALENDARIO DE TRABAJO MONTERESERVA | 0% | 0% |
| 192 | 1.3.16.8 | VENTANERIA APTOS 601 Y 602 ALTILLOS | 6d | 2015-11-05 | 2015-11-11 | 191 | 14d | 0d | CALENDARIO DE TRABAJO MONTERESERVA | 0% | 0% |
| 193 | 1.3.17 | **TRABAJOS DE CUBIERTA** | 28d | 2015-09-02 | 2015-10-10 |  | 0d |  | DIAS CALENDARIO 2 | 0% | 0% |
| 194 | 1.3.17.1 | CARGUE Y PENDIENTADO DE PISO | 6d | 2015-09-02 | 2015-09-08 | 134 | 0d |  | CALENDARIO DE TRABAJO MONTERESERVA | 0% | 0% |
| 195 | 1.3.17.2 | IMPERMEABILIZACION | 6d | 2015-09-09 | 2015-09-15 | 194 | 86d | 0d | CALENDARIO DE TRABAJO MONTERESERVA | 0% | 0% |
| 196 | 1.3.17.3 | AFINADO DE PISO 2 | 6d | 2015-09-16 | 2015-09-22 | 195 | 86d | 0d | CALENDARIO DE TRABAJO MONTERESERVA | 0% | 0% |
| 197 | 1.3.17.4 | ACABADO FINAL | 18d | 2015-09-21 | 2015-10-10 | 196FS-2d | 86d |  | CALENDARIO DE TRABAJO MONTERESERVA | 0% | 0% |
| 198 | 1.3.18 | **CAJAS ELECTRICAS Y CABLEADO ELECTRICO** | 36d | 2015-09-30 | 2015-11-18 |  | 58d |  | DIAS CALENDARIO 2 | 0% | 0% |
| 199 | 1.3.18.1 | CAJAS ELECTRICAS Y CABLEADO ELECTRICO. APTOS. 101 Y 102 | 5d | 2015-09-30 | 2015-10-05 | 186 | 91d |  | CALENDARIO DE TRABAJO MONTERESERVA | 0% | 0% |
| 200 | 1.3.18.2 | CAJAS ELECTRICAS Y CABLEADO ELECTRICO. LOBBY APTOS. 201 Y 202 | 5d | 2015-10-06 | 2015-10-10 | 187 | 86d |  | CALENDARIO DE TRABAJO MONTERESERVA | 0% | 0% |
| 201 | 1.3.18.3 | CAJAS ELECTRICAS Y CABLEADO ELECTRICO APTOS. 301 Y 302 | 5d | 2015-10-14 | 2015-10-19 | 188 | 80d |  | CALENDARIO DE TRABAJO MONTERESERVA | 0% | 0% |
| 202 | 1.3.18.4 | CAJAS ELECTRICAS Y CABLEADO ELECTRICO 401 Y 402 | 5d | 2015-10-21 | 2015-10-26 | 189 | 74d |  | CALENDARIO DE TRABAJO MONTERESERVA | 0% | 0% |
| 203 | 1.3.18.5 | CAJAS ELECTRICAS Y CABLEADO ELECTRICO 501 Y 502 | 5d | 2015-10-28 | 2015-11-03 | 190 | 68d |  | CALENDARIO DE TRABAJO MONTERESERVA | 0% | 0% |
| 204 | 1.3.18.6 | CAJAS ELECTRICAS Y CABLEADO ELECTRICO 601 Y 602 BAJILLOS | 5d | 2015-11-05 | 2015-11-10 | 191 | 62d |  | CALENDARIO DE TRABAJO MONTERESERVA | 0% | 0% |
| 205 | 1.3.18.7 | CAJAS ELECTRICAS Y CABLEADO ELECTRICO 601 Y 602 ALTILLOS | 5d | 2015-11-12 | 2015-11-18 | 192 | 56d |  | CALENDARIO DE TRABAJO MONTERESERVA | 0% | 0% |
| 206 | 1.4 | **TRABAJOS PUNTO FIJO** | 90d | 2015-09-12 | 2016-01-16 |  | 16d |  | DIAS CALENDARIO 2 | 0% | 0% |
| 207 | 1.4.1 | **PUNTO FIJO SOTANO** | 40d | 2015-09-19 | 2015-11-13 |  | 46d |  | DIAS CALENDARIO 2 | 0% | 0% |
| 208 | 1.4.1.1 | SHUT DE BASURAS | 4d | 2015-09-19 | 2015-09-23 | 224 | 53d | 0d | CALENDARIO DE TRABAJO MONTERESERVA | 0% | 0% |
| 209 | 1.4.1.2 | REMATES MAMPOSTERIA | 4d | 2015-09-24 | 2015-09-28 | 130, 208 | 53d | 0d | CALENDARIO DE TRABAJO MONTERESERVA | 0% | 0% |
| 210 | 1.4.1.3 | PROLONGACIONES ELECTRICAS | 1d | 2015-09-29 | 2015-09-29 | 209 | 53d | 0d | CALENDARIO DE TRABAJO MONTERESERVA | 0% | 0% |
| 211 | 1.4.1.4 | PAÑETES | 2d | 2015-09-30 | 2015-10-01 | 210 | 53d | 0d | CALENDARIO DE TRABAJO MONTERESERVA | 0% | 0% |
| 212 | 1.4.1.5 | ESTUCO Y PRIMERA MANO | 4d | 2015-10-02 | 2015-10-06 | 211 | 53d | 0d | CALENDARIO DE TRABAJO MONTERESERVA | 0% | 0% |
| 213 | 1.4.1.6 | AFINADO DE PISOS | 2d | 2015-10-07 | 2015-10-08 | 152, 212 | 53d | 0d | CALENDARIO DE TRABAJO MONTERESERVA | 0% | 0% |
| 214 | 1.4.1.7 | DETALLADO Y SEGUNDA MANO | 2d | 2015-10-09 | 2015-10-10 | 213 | 53d | 1d | CALENDARIO DE TRABAJO MONTERESERVA | 0% | 0% |
| 215 | 1.4.1.8 | INSTALACION TAPA SHUT | 2d | 2015-10-13 | 2015-10-14 | 208, 214 | 53d | 0d | CALENDARIO DE TRABAJO MONTERESERVA | 0% | 0% |
| 216 | 1.4.1.9 | INSTALACION DE PISOS | 12d | 2015-10-15 | 2015-10-28 | 215 | 53d | 0d | CALENDARIO DE TRABAJO MONTERESERVA | 0% | 0% |
| 217 | 1.4.1.10 | PASAMANOS | 2d | 2015-10-29 | 2015-10-30 | 216 | 53d | 0d | CALENDARIO DE TRABAJO MONTERESERVA | 0% | 0% |
| 218 | 1.4.1.11 | EQUIPOS CONTRAINCENDIO | 2d | 2015-10-31 | 2015-11-03 | 217 | 53d | 0d | CALENDARIO DE TRABAJO MONTERESERVA | 0% | 0% |
| 219 | 1.4.1.12 | PUERTAS ACCESO EN MADERA | 1d | 2015-11-04 | 2015-11-04 | 218 | 53d | 0d | CALENDARIO DE TRABAJO MONTERESERVA | 0% | 0% |
| 220 | 1.4.1.13 | DETALLADO Y TERCERA MANO DE PINTURA | 2d | 2015-11-05 | 2015-11-06 | 219 | 53d | 0d | CALENDARIO DE TRABAJO MONTERESERVA | 0% | 0% |
| 221 | 1.4.1.14 | ASEO PREENTREGA ( INCLUYE APTO) | 6d | 2015-11-07 | 2015-11-13 | 220 | 53d | 40d | CALENDARIO DE TRABAJO MONTERESERVA | 0% | 0% |

| ID | WBS | Task | Duration | Start | Finish | Predecessors | Total slack | Free slack | Calendar | Text1 | Text2 |
| --- | --- | --- | --- | --- | --- | --- | --- | --- | --- | --- | --- |
| 222 | 1.4.2 | **PUNTO FIJO LOBBY** | 42d | 2015-09-12 | 2015-11-10 |  | 41d |  | DIAS CALENDARIO 2 | 0% | 0% |
| 223 | 1.4.2.1 | SHUT DE BASURAS | 4d | 2015-09-12 | 2015-09-17 | 224SF | 82d | 17d | CALENDARIO DE TRABAJO MONTERESERVA | 0% | 0% |
| 224 | 1.4.2.2 | REMATES MAMPOSTERIA | 2d | 2015-09-17 | 2015-09-19 | 160SF, 187SF-9d | 44d | 0d | CALENDARIO DE TRABAJO MONTERESERVA | 0% | 0% |
| 225 | 1.4.2.3 | PROLONGACIONES ELECTRICAS | 2d | 2015-09-19 | 2015-09-21 | 224 | 62d | 0d | CALENDARIO DE TRABAJO MONTERESERVA | 0% | 0% |
| 226 | 1.4.2.4 | PAÑETES | 2d | 2015-09-22 | 2015-09-23 | 225 | 62d | 0d | CALENDARIO DE TRABAJO MONTERESERVA | 0% | 0% |
| 227 | 1.4.2.5 | ESTUCO Y PRIMERA MANO | 4d | 2015-10-01 | 2015-10-05 | 226FS+6d | 62d | 0d | CALENDARIO DE TRABAJO MONTERESERVA | 0% | 0% |
| 228 | 1.4.2.6 | AFINADO DE PISOS | 2d | 2015-10-06 | 2015-10-07 | 227, 153 | 62d | 0d | CALENDARIO DE TRABAJO MONTERESERVA | 0% | 0% |
| 229 | 1.4.2.7 | DETALLADO Y SEGUNDA MANO | 2d | 2015-10-08 | 2015-10-09 | 228 | 62d | 0d | CALENDARIO DE TRABAJO MONTERESERVA | 0% | 0% |
| 230 | 1.4.2.8 | INSTALACION TAPA SHUT | 2d | 2015-10-10 | 2015-10-13 | 229, 223 | 62d | 0d | CALENDARIO DE TRABAJO MONTERESERVA | 0% | 0% |
| 231 | 1.4.2.9 | INSTALACION DE PISOS | 12d | 2015-10-10 | 2015-10-24 | 230SS | 62d | 0d | CALENDARIO DE TRABAJO MONTERESERVA | 0% | 0% |
| 232 | 1.4.2.10 | PASAMANOS | 2d | 2015-10-26 | 2015-10-27 | 231 | 62d | 0d | CALENDARIO DE TRABAJO MONTERESERVA | 0% | 0% |
| 233 | 1.4.2.11 | EQUIPOS CONTRAINCENDIO | 2d | 2015-10-28 | 2015-10-29 | 232 | 62d | 0d | CALENDARIO DE TRABAJO MONTERESERVA | 0% | 0% |
| 234 | 1.4.2.12 | PUERTAS ACCESO EN MADERA | 1d | 2015-10-30 | 2015-10-30 | 233 | 62d | 0d | CALENDARIO DE TRABAJO MONTERESERVA | 0% | 0% |
| 235 | 1.4.2.13 | DETALLADO Y TERCERA MANO DE PINTURA | 2d | 2015-10-31 | 2015-11-03 | 234 | 62d | 0d | CALENDARIO DE TRABAJO MONTERESERVA | 0% | 0% |
| 236 | 1.4.2.14 | ASEO PREENTREGA ( INCLUYE APTO) | 6d | 2015-11-04 | 2015-11-10 | 235 | 62d |  | CALENDARIO DE TRABAJO MONTERESERVA | 0% | 0% |
| 237 | 1.4.3 | **PUNTO FIJO P2** | 37d | 2015-10-01 | 2015-11-21 |  | 30d |  | DIAS CALENDARIO 2 | 0% | 0% |
| 238 | 1.4.3.1 | SHUT DE BASURAS | 4d | 2015-10-01 | 2015-10-06 | 239SF | 70d | 15d | CALENDARIO DE TRABAJO MONTERESERVA | 0% | 0% |
| 239 | 1.4.3.2 | REMATES MAMPOSTERIA | 2d | 2015-10-06 | 2015-10-07 | 224, 161, 188SS | 30d | 0d | CALENDARIO DE TRABAJO MONTERESERVA | 0% | 0% |
| 240 | 1.4.3.3 | PROLONGACIONES ELECTRICAS | 1d | 2015-10-08 | 2015-10-08 | 239 | 53d | 0d | CALENDARIO DE TRABAJO MONTERESERVA | 0% | 0% |
| 241 | 1.4.3.4 | PAÑETES | 2d | 2015-10-09 | 2015-10-10 | 240 | 53d | 1d | CALENDARIO DE TRABAJO MONTERESERVA | 0% | 0% |
| 242 | 1.4.3.5 | ESTUCO Y PRIMERA MANO | 2d | 2015-10-20 | 2015-10-21 | 241FS+6d | 53d | 0d | CALENDARIO DE TRABAJO MONTERESERVA | 0% | 0% |
| 243 | 1.4.3.6 | AFINADO DE PISOS | 2d | 2015-10-22 | 2015-10-23 | 242, 154 | 53d | 0d | CALENDARIO DE TRABAJO MONTERESERVA | 0% | 0% |
| 244 | 1.4.3.7 | DETALLADO Y SEGUNDA MANO | 2d | 2015-10-24 | 2015-10-26 | 243 | 53d | 0d | CALENDARIO DE TRABAJO MONTERESERVA | 0% | 0% |
| 245 | 1.4.3.8 | INSTALACION TAPA SHUT | 2d | 2015-10-27 | 2015-10-28 | 244, 238 | 53d | 0d | CALENDARIO DE TRABAJO MONTERESERVA | 0% | 0% |
| 246 | 1.4.3.9 | INSTALACION DE PISOS | 6d | 2015-10-29 | 2015-11-05 | 245 | 53d | 0d | CALENDARIO DE TRABAJO MONTERESERVA | 0% | 0% |
| 247 | 1.4.3.10 | PASAMANOS | 2d | 2015-11-06 | 2015-11-07 | 246 | 53d | 0d | CALENDARIO DE TRABAJO MONTERESERVA | 0% | 0% |
| 248 | 1.4.3.11 | EQUIPOS CONTRAINCENDIO | 2d | 2015-11-09 | 2015-11-10 | 247 | 53d | 0d | CALENDARIO DE TRABAJO MONTERESERVA | 0% | 0% |
| 249 | 1.4.3.12 | PUERTAS ACCESO EN MADERA | 1d | 2015-11-11 | 2015-11-11 | 248 | 53d | 0d | CALENDARIO DE TRABAJO MONTERESERVA | 0% | 0% |
| 250 | 1.4.3.13 | DETALLADO Y TERCERA MANO DE PINTURA | 2d | 2015-11-12 | 2015-11-13 | 249 | 53d | 0d | CALENDARIO DE TRABAJO MONTERESERVA | 0% | 0% |
| 251 | 1.4.3.14 | ASEO PREENTREGA ( INCLUYE APTO) | 6d | 2015-11-14 | 2015-11-21 | 250 | 53d |  | CALENDARIO DE TRABAJO MONTERESERVA | 0% | 0% |

| ID | WBS | Task | Duration | Start | Finish | Predecessors | Total slack | Free slack | Calendar | Text1 | Text2 |
| --- | --- | --- | --- | --- | --- | --- | --- | --- | --- | --- | --- |
| 252 | 1.4.4 | **PUNTO FIJO P3** | 38d | 2015-10-07 | 2015-11-27 |  | 28d |  | DIAS CALENDARIO 2 | 0% | 0% |
| 253 | 1.4.4.1 | SHUT DE BASURAS | 4d | 2015-10-07 | 2015-10-13 | 254SF | 65d | 15d | CALENDARIO DE TRABAJO MONTERESERVA | 0% | 0% |
| 254 | 1.4.4.2 | REMATES MAMPOSTERIA | 2d | 2015-10-13 | 2015-10-14 | 239, 162, 189SS-1d | 27d | 0d | CALENDARIO DE TRABAJO MONTERESERVA | 0% | 0% |
| 255 | 1.4.4.3 | PROLONGACIONES ELECTRICAS | 1d | 2015-10-15 | 2015-10-15 | 254 | 48d | 0d | CALENDARIO DE TRABAJO MONTERESERVA | 0% | 0% |
| 256 | 1.4.4.4 | PAÑETES | 2d | 2015-10-16 | 2015-10-17 | 255 | 48d | 0d | CALENDARIO DE TRABAJO MONTERESERVA | 0% | 0% |
| 257 | 1.4.4.5 | ESTUCO Y PRIMERA MANO | 2d | 2015-10-26 | 2015-10-27 | 256FS+6d | 48d | 0d | CALENDARIO DE TRABAJO MONTERESERVA | 0% | 0% |
| 258 | 1.4.4.6 | AFINADO DE PISOS | 2d | 2015-10-28 | 2015-10-29 | 257, 155 | 48d | 0d | CALENDARIO DE TRABAJO MONTERESERVA | 0% | 0% |
| 259 | 1.4.4.7 | DETALLADO Y SEGUNDA MANO | 2d | 2015-10-30 | 2015-10-31 | 258 | 48d | 1d | CALENDARIO DE TRABAJO MONTERESERVA | 0% | 0% |
| 260 | 1.4.4.8 | INSTALACION TAPA SHUT | 2d | 2015-11-03 | 2015-11-04 | 259, 253 | 48d | 0d | CALENDARIO DE TRABAJO MONTERESERVA | 0% | 0% |
| 261 | 1.4.4.9 | INSTALACION DE PISOS | 6d | 2015-11-05 | 2015-11-11 | 260 | 48d | 0d | CALENDARIO DE TRABAJO MONTERESERVA | 0% | 0% |
| 262 | 1.4.4.10 | PASAMANOS | 2d | 2015-11-12 | 2015-11-13 | 261 | 48d | 0d | CALENDARIO DE TRABAJO MONTERESERVA | 0% | 0% |
| 263 | 1.4.4.11 | EQUIPOS CONTRAINCENDIO | 2d | 2015-11-14 | 2015-11-17 | 262 | 48d | 0d | CALENDARIO DE TRABAJO MONTERESERVA | 0% | 0% |
| 264 | 1.4.4.12 | PUERTAS ACCESO EN MADERA | 1d | 2015-11-18 | 2015-11-18 | 263 | 48d | 0d | CALENDARIO DE TRABAJO MONTERESERVA | 0% | 0% |
| 265 | 1.4.4.13 | DETALLADO Y TERCERA MANO DE PINTURA | 2d | 2015-11-19 | 2015-11-20 | 264 | 48d | 0d | CALENDARIO DE TRABAJO MONTERESERVA | 0% | 0% |
| 266 | 1.4.4.14 | ASEO PREENTREGA ( INCLUYE APTO) | 6d | 2015-11-21 | 2015-11-27 | 265 | 48d |  | CALENDARIO DE TRABAJO MONTERESERVA | 0% | 0% |
| 267 | 1.4.5 | **PUNTO FIJO P4** | 37d | 2015-10-15 | 2015-12-04 |  | 24d |  | DIAS CALENDARIO 2 | 0% | 0% |
| 268 | 1.4.5.1 | SHUT DE BAURAS | 4d | 2015-10-15 | 2015-10-20 | 269SF | 59d | 15d | CALENDARIO DE TRABAJO MONTERESERVA | 0% | 0% |
| 269 | 1.4.5.2 | REMATES MAMPOSTERIA | 2d | 2015-10-20 | 2015-10-21 | 254, 163, 190SS-1d | 23d | 0d | CALENDARIO DE TRABAJO MONTERESERVA | 0% | 0% |
| 270 | 1.4.5.3 | PROLONGACIONES ELECTRICAS | 1d | 2015-10-22 | 2015-10-22 | 269 | 42d | 0d | CALENDARIO DE TRABAJO MONTERESERVA | 0% | 0% |
| 271 | 1.4.5.4 | PAÑETES | 2d | 2015-10-23 | 2015-10-24 | 270 | 42d | 0d | CALENDARIO DE TRABAJO MONTERESERVA | 0% | 0% |
| 272 | 1.4.5.5 | ESTUCO Y PRIMERA MANO | 2d | 2015-11-03 | 2015-11-04 | 271FS+6d | 42d | 0d | CALENDARIO DE TRABAJO MONTERESERVA | 0% | 0% |
| 273 | 1.4.5.6 | AFINADO DE PISOS | 2d | 2015-11-05 | 2015-11-06 | 272, 156 | 42d | 0d | CALENDARIO DE TRABAJO MONTERESERVA | 0% | 0% |
| 274 | 1.4.5.7 | DETALLADO Y SEGUNDA MANO | 2d | 2015-11-07 | 2015-11-09 | 273 | 42d | 0d | CALENDARIO DE TRABAJO MONTERESERVA | 0% | 0% |
| 275 | 1.4.5.8 | INSTALACION TAPA SHUT | 2d | 2015-11-10 | 2015-11-11 | 274, 268 | 42d | 0d | CALENDARIO DE TRABAJO MONTERESERVA | 0% | 0% |
| 276 | 1.4.5.9 | INSTALACION DE PISOS | 6d | 2015-11-12 | 2015-11-19 | 275 | 42d | 0d | CALENDARIO DE TRABAJO MONTERESERVA | 0% | 0% |
| 277 | 1.4.5.10 | PASAMANOS | 2d | 2015-11-20 | 2015-11-21 | 276 | 42d | 0d | CALENDARIO DE TRABAJO MONTERESERVA | 0% | 0% |
| 278 | 1.4.5.11 | EQUIPOS CONTRAINCENDIO | 2d | 2015-11-23 | 2015-11-24 | 277 | 42d | 0d | CALENDARIO DE TRABAJO MONTERESERVA | 0% | 0% |
| 279 | 1.4.5.12 | PUERTAS ACCESO EN MADERA | 1d | 2015-11-25 | 2015-11-25 | 278 | 42d | 0d | CALENDARIO DE TRABAJO MONTERESERVA | 0% | 0% |
| 280 | 1.4.5.13 | DETALLADO Y TERCERA MANO DE PINTURA | 2d | 2015-11-26 | 2015-11-27 | 279 | 42d | 0d | CALENDARIO DE TRABAJO MONTERESERVA | 0% | 0% |
| 281 | 1.4.5.14 | ASEO PREENTREGA ( INCLUYE APTO) | 6d | 2015-11-28 | 2015-12-04 | 280 | 42d |  | CALENDARIO DE TRABAJO MONTERESERVA | 0% | 0% |

| ID | WBS | Task | Duration | Start | Finish | Predecessors | Total slack | Free slack | Calendar | Text1 | Text2 |
| --- | --- | --- | --- | --- | --- | --- | --- | --- | --- | --- | --- |
| 282 | 1.4.6 | **PUNTO FIJO P5** | 36d | 2015-10-17 | 2015-12-07 |  | 24d |  | DIAS CALENDARIO 2 | 0% | 0% |
| 283 | 1.4.6.1 | SHUT DE BASURAS | 4d | 2015-10-17 | 2015-10-22 | 284SF | 57d | 15d | CALENDARIO DE TRABAJO MONTERESERVA | 0% | 0% |
| 284 | 1.4.6.2 | REMATES MAMPOSTERIA | 2d | 2015-10-22 | 2015-10-23 | 269, 164 | 23d | 0d | CALENDARIO DE TRABAJO MONTERESERVA | 0% | 0% |
| 285 | 1.4.6.3 | PROLONGACIONES ELECTRICAS | 1d | 2015-10-24 | 2015-10-24 | 284 | 40d | 0d | CALENDARIO DE TRABAJO MONTERESERVA | 0% | 0% |
| 286 | 1.4.6.4 | PAÑETES | 2d | 2015-10-26 | 2015-10-27 | 285 | 40d | 0d | CALENDARIO DE TRABAJO MONTERESERVA | 0% | 0% |
| 287 | 1.4.6.5 | ESTUCO Y PRIMERA MANO | 2d | 2015-11-05 | 2015-11-06 | 286FS+6d | 40d | 0d | CALENDARIO DE TRABAJO MONTERESERVA | 0% | 0% |
| 288 | 1.4.6.6 | AFINADO DE PISOS | 2d | 2015-11-07 | 2015-11-09 | 287, 157 | 40d | 0d | CALENDARIO DE TRABAJO MONTERESERVA | 0% | 0% |
| 289 | 1.4.6.7 | DETALLADO Y SEGUNDA MANO | 2d | 2015-11-10 | 2015-11-11 | 288 | 40d | 0d | CALENDARIO DE TRABAJO MONTERESERVA | 0% | 0% |
| 290 | 1.4.6.8 | INSTALACION TAPA SHUT | 2d | 2015-11-12 | 2015-11-13 | 289, 283 | 40d | 0d | CALENDARIO DE TRABAJO MONTERESERVA | 0% | 0% |
| 291 | 1.4.6.9 | INSTALACION DE PISOS | 6d | 2015-11-14 | 2015-11-21 | 290 | 40d | 0d | CALENDARIO DE TRABAJO MONTERESERVA | 0% | 0% |
| 292 | 1.4.6.10 | PASAMANOS | 2d | 2015-11-23 | 2015-11-24 | 291 | 40d | 0d | CALENDARIO DE TRABAJO MONTERESERVA | 0% | 0% |
| 293 | 1.4.6.11 | EQUIPOS CONTRAINCENDIO | 2d | 2015-11-25 | 2015-11-26 | 292 | 40d | 0d | CALENDARIO DE TRABAJO MONTERESERVA | 0% | 0% |
| 294 | 1.4.6.12 | PUERTAS ACCESO EN MADERA | 1d | 2015-11-27 | 2015-11-27 | 293 | 40d | 0d | CALENDARIO DE TRABAJO MONTERESERVA | 0% | 0% |
| 295 | 1.4.6.13 | DETALLADO Y TERCERA MANO DE PINTURA | 2d | 2015-11-28 | 2015-11-30 | 294 | 40d | 0d | CALENDARIO DE TRABAJO MONTERESERVA | 0% | 0% |
| 296 | 1.4.6.14 | ASEO PREENTREGA ( INCLUYE APTO) | 6d | 2015-12-01 | 2015-12-07 | 295 | 40d |  | CALENDARIO DE TRABAJO MONTERESERVA | 0% | 0% |
| 297 | 1.4.7 | **PUNTO FIJO P6** | 56d | 2015-10-30 | 2016-01-16 |  | 4d |  | DIAS CALENDARIO 2 | 0% | 0% |
| 298 | 1.4.7.1 | SHUT BASURAS | 4d | 2015-10-30 | 2015-11-05 | 299SF | 31d | 15d | CALENDARIO DE TRABAJO MONTERESERVA | 0% | 0% |
| 299 | 1.4.7.2 | REMATES MAMPOSTERIA | 2d | 2015-11-05 | 2015-11-06 | 284, 165, 192SS | 14d | 0d | CALENDARIO DE TRABAJO MONTERESERVA | 0% | 0% |
| 300 | 1.4.7.3 | PROLONGACIONES ELECTRICAS | 1d | 2015-11-07 | 2015-11-07 | 299 | 14d | 0d | CALENDARIO DE TRABAJO MONTERESERVA | 0% | 0% |
| 301 | 1.4.7.4 | PAÑETES | 2d | 2015-11-09 | 2015-11-10 | 300 | 14d | 0d | CALENDARIO DE TRABAJO MONTERESERVA | 0% | 0% |
| 302 | 1.4.7.5 | AFINADO DE PISOS | 2d | 2015-11-11 | 2015-11-12 | 301, 158 | 20d | 6d | CALENDARIO DE TRABAJO MONTERESERVA | 0% | 0% |
| 303 | 1.4.7.6 | ESTUCO Y PRIMERA MANO | 2d | 2015-11-21 | 2015-11-23 | 301FS+8d, 302 | 14d | 0d | CALENDARIO DE TRABAJO MONTERESERVA | 0% | 0% |
| 304 | 1.4.7.7 | DETALLADO Y SEGUNDA MANO | 2d | 2015-11-24 | 2015-11-25 | 303 | 14d | 0d | CALENDARIO DE TRABAJO MONTERESERVA | 0% | 0% |
| 305 | 1.4.7.8 | INSTALACION TAPA SHUT | 2d | 2015-11-26 | 2015-11-27 | 304, 298 | 14d | 0d | CALENDARIO DE TRABAJO MONTERESERVA | 0% | 0% |
| 306 | 1.4.7.9 | INSTALACION DE PISOS | 6d | 2015-11-28 | 2015-12-04 | 305 | 14d | 0d | CALENDARIO DE TRABAJO MONTERESERVA | 0% | 0% |
| 307 | 1.4.7.10 | PASAMANOS | 2d | 2015-12-05 | 2015-12-07 | 306 | 14d | 1d | CALENDARIO DE TRABAJO MONTERESERVA | 0% | 0% |
| 308 | 1.4.7.11 | EQUIPOS CONTRAINCENDIO | 2d | 2015-12-09 | 2015-12-10 | 307 | 14d | 0d | CALENDARIO DE TRABAJO MONTERESERVA | 0% | 0% |
| 309 | 1.4.7.12 | PUERTAS EN MADERA | 1d | 2015-12-11 | 2015-12-11 | 308 | 14d | 0d | CALENDARIO DE TRABAJO MONTERESERVA | 0% | 0% |
| 310 | 1.4.7.13 | DETALLADO Y TERCERA MANO DE PINTURA | 2d | 2015-12-12 | 2015-12-14 | 309 | 14d |  | CALENDARIO DE TRABAJO MONTERESERVA | 0% | 0% |
| 311 | 1.4.7.14 | ASEO PREENTREGA ( INCLUYE APTO) | 6d | 2016-01-09 | 2016-01-16 | 310, 183, 360 | 4d | 0d | CALENDARIO DE TRABAJO MONTERESERVA | 0% | 0% |

| ID | WBS | Task | Type | Duration | Start | Finish | Predecessors | Total slack | Free slack | Calendar | Text1 | Text2 |
| --- | --- | --- | --- | --- | --- | --- | --- | --- | --- | --- | --- | --- |
| 312 | 1.5 | **ENTREGAS A PROPIETARIOS ( OBRA GRIS )** |  | 0d | 2016-01-08 | 2016-01-08 |  | 21d |  | DIAS CALENDARIO 2 | 0% | 0% |
| 313 | 1.5.1 | **CIERRE APARTAMENTOS EN OBRA GRIS** |  | 0d | 2016-01-08 | 2016-01-08 |  | 21d |  | DIAS CALENDARIO 2 | 0% | 0% |
| 314 | 1.5.1.1 | APARTAMENTOS 101 Y 102 | milestone | 0d | 2016-01-08 | 2016-01-08 | 186, 357 | 21d | 0d | DIAS CALENDARIO | 0% | 0% |
| 315 | 1.5.1.2 | APARTAMENTOS 201 Y 202 | milestone | 0d | 2016-01-08 | 2016-01-08 | 314, 187 | 21d | 0d | DIAS CALENDARIO | 0% | 0% |
| 316 | 1.5.1.3 | APARTAMENTOS 301 Y 302 | milestone | 0d | 2016-01-08 | 2016-01-08 | 315, 188 | 21d | 0d | DIAS CALENDARIO | 0% | 0% |
| 317 | 1.5.1.4 | APARTAMENTOS 401 Y 402 | milestone | 0d | 2016-01-08 | 2016-01-08 | 316, 189 | 21d | 0d | DIAS CALENDARIO | 0% | 0% |
| 318 | 1.5.1.5 | APARTAMENTOS 501 Y 502 | milestone | 0d | 2016-01-08 | 2016-01-08 | 317, 190 | 21d | 0d | DIAS CALENDARIO | 0% | 0% |
| 319 | 1.5.1.6 | APARTAMENTOS 601 Y 602 | milestone | 0d | 2016-01-08 | 2016-01-08 | 318, 192 | 21d |  | DIAS CALENDARIO | 0% | 0% |
| 320 | 1.6 | **OBRAS EXTERIORES** |  | 124d | 2015-08-14 | 2016-02-03 |  | 3d |  | DIAS CALENDARIO 2 | 0% | 0% |
| 321 | 1.6.1 | **PARQUEADEROS DE VISITANTES** |  | 49d | 2015-11-27 | 2016-02-03 |  | 3d |  | DIAS CALENDARIO 2 | 0% | 0% |
| 322 | 1.6.1.1 | PARQUEADERO DE VISITANTES |  | 45d | 2015-11-27 | 2016-02-03 | 311FF+15d | 4d |  | CALENDARIO DE TRABAJO MONTERESERVA | 0% | 0% |
| 323 | 1.6.2 | **ACABADOS LOBBY** |  | 74d | 2015-10-13 | 2016-01-23 |  | 11d |  | DIAS CALENDARIO 2 | 0% | 0% |
| 324 | 1.6.2.1 | ENCHAPES BAÑOS |  | 6d | 2015-10-13 | 2015-10-19 | 325SF+3d | 80d |  | CALENDARIO DE TRABAJO MONTERESERVA | 0% | 0% |
| 325 | 1.6.2.2 | PISOS 1/4 x 26 |  | 12d | 2015-10-16 | 2015-10-29 | 326SF+3d | 71d | 0d | CALENDARIO DE TRABAJO MONTERESERVA | 0% | 0% |
| 326 | 1.6.2.3 | ESTUCO Y PRIMERA MANO DE PINTURA |  | 8d | 2015-10-27 | 2015-11-05 | 327SF+3d | 66d | 0d | CALENDARIO DE TRABAJO MONTERESERVA | 0% | 0% |
| 327 | 1.6.2.4 | INSTALACION PISO HALL DE ASCENSOR |  | 4d | 2015-11-03 | 2015-11-06 | 328SF+3d | 65d | 0d | CALENDARIO DE TRABAJO MONTERESERVA | 0% | 0% |
| 328 | 1.6.2.5 | INSTALACION CIELO EN DRY WALL |  | 18d | 2015-11-04 | 2015-11-25 | 329SF+3d | 50d | 0d | CALENDARIO DE TRABAJO MONTERESERVA | 0% | 0% |
| 329 | 1.6.2.6 | DETALLADO Y SEGUNDA MANO DE PINTURA |  | 10d | 2015-11-23 | 2015-12-03 | 330SF+3d | 43d | 0d | CALENDARIO DE TRABAJO MONTERESERVA | 0% | 0% |
| 330 | 1.6.2.7 | REMATES VENTANERIA |  | 4d | 2015-12-01 | 2015-12-04 | 331SF+3d | 42d | 0d | CALENDARIO DE TRABAJO MONTERESERVA | 0% | 0% |
| 331 | 1.6.2.8 | CARPINTERIA MADERA |  | 18d | 2015-12-02 | 2016-01-06 | 332SF+3d | 27d | 0d | CALENDARIO DE TRABAJO MONTERESERVA | 0% | 0% |
| 332 | 1.6.2.9 | APARATOS SANITARIOS |  | 6d | 2016-01-04 | 2016-01-09 | 333SF+3d | 24d | 0d | CALENDARIO DE TRABAJO MONTERESERVA | 0% | 0% |
| 333 | 1.6.2.10 | INSTALACION GUARDAESCOBA |  | 3d | 2016-01-07 | 2016-01-09 | 334 | 24d | 0d | CALENDARIO DE TRABAJO MONTERESERVA | 0% | 0% |
| 334 | 1.6.2.11 | APARATOS ELECTRICOS |  | 3d | 2016-01-04 | 2016-01-06 | 335SF+2d | 24d | 0d | CALENDARIO DE TRABAJO MONTERESERVA | 0% | 0% |
| 335 | 1.6.2.12 | SEGUNDA MANO DE PINTURA |  | 8d | 2016-01-05 | 2016-01-14 | 336SF+2d | 21d | 0d | CALENDARIO DE TRABAJO MONTERESERVA | 0% | 0% |
| 336 | 1.6.2.13 | DETALLADO FINAL Y TERCERA MANO DE PINTURA |  | 6d | 2016-01-13 | 2016-01-19 | 337SF+2d | 17d | 0d | CALENDARIO DE TRABAJO MONTERESERVA | 0% | 0% |
| 337 | 1.6.2.14 | ASEO FINAL |  | 6d | 2016-01-18 | 2016-01-23 | 311 | 13d | 0d | CALENDARIO DE TRABAJO MONTERESERVA | 0% | 0% |

| ID | WBS | Task | Duration | Start | Finish | Predecessors | Total slack | Free slack | Calendar | Text1 | Text2 |
| --- | --- | --- | --- | --- | --- | --- | --- | --- | --- | --- | --- |
| 338 | 1.6.3 | **ACABADOS NIVEL -SOTANO** | 106d | 2015-08-14 | 2016-01-08 |  | 21d |  | DIAS CALENDARIO 2 | 0% | 0% |
| 339 | 1.6.3.1 | ADECUACIONES TERRENO | 12d | 2015-08-14 | 2015-08-28 | 132 | 25d | 0d | CALENDARIO DE TRABAJO MONTERESERVA | 0% | 0% |
| 340 | 1.6.3.2 | FILTROS | 12d | 2015-08-29 | 2015-09-11 | 339 | 25d | 0d | CALENDARIO DE TRABAJO MONTERESERVA | 0% | 0% |
| 341 | 1.6.3.3 | RELLENOS | 6d | 2015-09-12 | 2015-09-18 | 340 | 25d | 0d | CALENDARIO DE TRABAJO MONTERESERVA | 0% | 0% |
| 342 | 1.6.3.4 | PAVIMENTOS SOTANO | 6d | 2015-09-19 | 2015-09-25 | 341 | 25d | 0d | CALENDARIO DE TRABAJO MONTERESERVA | 0% | 0% |
| 343 | 1.6.3.5 | PAÑETES SOTANO | 6d | 2015-09-26 | 2015-10-02 | 342 | 25d | 0d | CALENDARIO DE TRABAJO MONTERESERVA | 0% | 0% |
| 344 | 1.6.3.6 | SOBREPISOS EN HALLES | 3d | 2015-10-03 | 2015-10-06 | 343 | 25d | 0d | CALENDARIO DE TRABAJO MONTERESERVA | 0% | 0% |
| 345 | 1.6.3.7 | ENCHAPE CUARTO DE BASURAS BAJO LA TORRE | 3d | 2015-10-07 | 2015-10-09 | 344 | 25d | 0d | CALENDARIO DE TRABAJO MONTERESERVA | 0% | 0% |
| 346 | 1.6.3.8 | ESTUCO Y PRIMERA MANO DE PINTURA | 6d | 2015-10-10 | 2015-10-17 | 345 | 25d | 0d | CALENDARIO DE TRABAJO MONTERESERVA | 0% | 0% |
| 347 | 1.6.3.9 | INSTALACION PISOS CERAMICOS O EN ARCILLA | 3d | 2015-10-19 | 2015-10-21 | 346 | 25d | 0d | CALENDARIO DE TRABAJO MONTERESERVA | 0% | 0% |
| 348 | 1.6.3.10 | INSTALACION CIELO EN DRY WALL | 6d | 2015-10-22 | 2015-10-28 | 347 | 25d | 0d | CALENDARIO DE TRABAJO MONTERESERVA | 0% | 0% |
| 349 | 1.6.3.11 | PUERTAS DEPOSITOS | 2d | 2015-10-29 | 2015-10-30 | 348 | 25d | 0d | CALENDARIO DE TRABAJO MONTERESERVA | 0% | 0% |
| 350 | 1.6.3.12 | INSTALACION TOPELLANTAS | 2d | 2015-10-31 | 2015-11-03 | 349 | 25d | 0d | CALENDARIO DE TRABAJO MONTERESERVA | 0% | 0% |
| 351 | 1.6.3.13 | DEMARCACION PARQUEADEROS | 2d | 2015-11-04 | 2015-11-05 | 350 | 25d | 0d | CALENDARIO DE TRABAJO MONTERESERVA | 0% | 0% |
| 352 | 1.6.3.14 | PINTURAS CIELOS | 12d | 2015-11-06 | 2015-11-20 | 351 | 25d | 0d | CALENDARIO DE TRABAJO MONTERESERVA |  |  |
| 353 | 1.6.3.15 | PINTURAS REFLECTIVAS COLUMNAS | 2d | 2015-11-21 | 2015-11-23 | 352 | 25d | 0d | CALENDARIO DE TRABAJO MONTERESERVA | 0% | 0% |
| 354 | 1.6.3.16 | PINTURAS REFLECTIVAS MUROS | 3d | 2015-11-24 | 2015-11-26 | 353 | 25d | 0d | CALENDARIO DE TRABAJO MONTERESERVA | 0% | 0% |
| 355 | 1.6.3.17 | PUERTA DE ACCESO VEHICULAR | 6d | 2015-11-27 | 2015-12-03 | 354 | 25d | 0d | CALENDARIO DE TRABAJO MONTERESERVA | 0% | 0% |
| 356 | 1.6.3.18 | REMATES GENERALES PINTURA | 12d | 2015-12-04 | 2015-12-18 | 355 | 25d | 0d | CALENDARIO DE TRABAJO MONTERESERVA | 0% | 0% |
| 357 | 1.6.3.19 | ASEO | 6d | 2015-12-19 | 2016-01-08 | 356, 221FF, 397FF | 25d | 0d | CALENDARIO DE TRABAJO MONTERESERVA | 0% | 0% |
| 358 | 1.7 | **EQUIPOS ESPECIALES** | 151d | 2015-06-23 | 2016-01-19 |  | 14d |  | DIAS CALENDARIO 2 | 0% | 0% |
| 359 | 1.7.1 | **ASCENSORES** | 90d | 2015-09-07 | 2016-01-08 |  | 4d |  | DIAS CALENDARIO 2 | 0% | 0% |
| 360 | 1.7.1.1 | MONTAJE ASCESOR | 90d | 2015-09-07 | 2016-01-08 | 474FF | 4d | 0d | DIAS CALENDARIO | 0% | 0% |
| 361 | 1.7.2 | **SUB-ESTACION ELECTRICA** | 54d | 2015-06-23 | 2015-09-07 |  | 102d |  | DIAS CALENDARIO 2 | 0% | 0% |
| 362 | 1.7.2.1 | CANALIZACION A SUBESTACION | 61d | 2015-06-23 | 2015-09-07 | 360SF | 116d |  | CALENDARIO DE TRABAJO MONTERESERVA | 0% | 0% |

| ID | WBS | Task | Type | Duration | Start | Finish | Predecessors | Total slack | Free slack | Calendar | Text1 | Text2 |
| --- | --- | --- | --- | --- | --- | --- | --- | --- | --- | --- | --- | --- |
| 363 | 1.7.3 | **MEDIDORES ELECTRICOS** |  | 90d | 2015-09-16 | 2016-01-19 |  | 14d |  | DIAS CALENDARIO 2 | 0% | 0% |
| 364 | 1.7.3.1 | INICIO TRAMITES | milestone | 0d | 2015-09-16 | 2015-09-16 | 365SF-60d | 104d |  | DIAS CALENDARIO | 0% | 0% |
| 365 | 1.7.3.2 | CONTADORES |  | 30d | 2015-12-09 | 2016-01-19 | 134FF, 221FF+5d, 500FF | 14d | 0d | DIAS CALENDARIO | 0% | 0% |
| 366 | 1.7.4 | **MEDIDORES DE AGUA** |  | 30d | 2015-12-09 | 2016-01-19 |  | 14d |  | DIAS CALENDARIO 2 | 0% | 0% |
| 367 | 1.7.4.1 | MEDIDORES |  | 30d | 2015-12-09 | 2016-01-19 | 134FF, 221FF+5d, 500FF | 14d |  | DIAS CALENDARIO | 0% | 0% |
| 368 | 1.7.5 | **SISTEMA DE CITOFONIA - CIRCUITO CERRADO DE TV.** |  | 60d | 2015-10-28 | 2016-01-19 |  | 14d |  | DIAS CALENDARIO 2 | 0% | 0% |
| 369 | 1.7.5.1 | SISTEMA DE COMUNICACIÓN PORTERIA - CIRCUITO CERRADO DE TV. |  | 60d | 2015-10-28 | 2016-01-19 | 221FF+5d, 500FF | 14d |  | DIAS CALENDARIO | 0% | 0% |
| 370 | 1.7.6 | **PLANTA DE EMERGENCIA** |  | 58d | 2015-09-07 | 2015-11-25 |  | 44d |  | DIAS CALENDARIO 2 | 0% | 0% |
| 371 | 1.7.6.1 | INSTALACION PLANTA DE EMERGENCIA |  | 45d | 2015-09-07 | 2015-10-29 | 360SS | 50d | 0d | CALENDARIO DE TRABAJO MONTERESERVA | 0% | 0% |
| 372 | 1.7.6.2 | PRUEBAS PLANTA DE EMERGENCIA |  | 21d | 2015-10-30 | 2015-11-25 | 371 | 50d |  | CALENDARIO DE TRABAJO MONTERESERVA | 0% | 0% |
| 373 | 1.5.7 | **ACABADOS 101** |  | 64d | 2015-08-31 | 2015-11-26 |  | 2d |  | DIAS CALENDARIO 2 | 0% | 0% |
| 374 | 1.5.7.1 | ESTUCO Y PINTURA 1 |  | 6d | 2015-09-07 | 2015-09-12 | 144, 152, 194FS-2d | 2d | 0d | CALENDARIO DE TRABAJO MONTERESERVA | 0% | 0% |
| 375 | 1.5.7.3 | ENCHAPES BAÑOS Y COCINAS |  | 6d | 2015-09-14 | 2015-09-19 | 374 | 104d |  | CALENDARIO DE TRABAJO MONTERESERVA | 0% | 0% |
| 376 | 1.5.7.8 | ESTRUCTURA CIELO RASO |  | 6d | 2015-08-31 | 2015-09-07 | 374SF | 2d |  | CALENDARIO DE TRABAJO MONTERESERVA | 0% | 0% |
| 377 | 1.5.7.9 | EMPLACADO C.R |  | 6d | 2015-09-09 | 2015-09-15 | 376, 194 | 0d |  | CALENDARIO DE TRABAJO MONTERESERVA | 0% | 0% |
| 378 | 1.5.7.10 | MASILLA C.R |  | 6d | 2015-09-16 | 2015-09-22 | 377 | 0d |  | CALENDARIO DE TRABAJO MONTERESERVA | 0% | 0% |
| 379 | 1.5.7.11 | PINTURA C.R |  | 6d | 2015-09-23 | 2015-09-29 | 378 | 0d |  | CALENDARIO DE TRABAJO MONTERESERVA | 0% | 0% |
| 380 | 1.5.7.12 | PINTURA 2 |  | 8d | 2015-09-30 | 2015-10-08 | 186, 379, 377, 374 | 0d |  | CALENDARIO DE TRABAJO MONTERESERVA | 0% | 0% |
| 381 | 1.5.7.23 | APARATOS SANITARIOS |  | 3d | 2015-10-09 | 2015-10-13 | 380 | 32d | 0d | CALENDARIO DE TRABAJO MONTERESERVA | 0% | 0% |
| 382 | 1.8.9 | DIVISIONES DE DUCHAS |  | 3d | 2015-10-14 | 2015-10-16 | 381 | 32d | 0d | CALENDARIO DE TRABAJO MONTERESERVA | 0% | 0% |
| 383 | 1.8.10 | ASEO PARA INSTALACION PISO |  | 2d | 2015-10-17 | 2015-10-19 | 382 | 32d | 0d | CALENDARIO DE TRABAJO MONTERESERVA | 0% | 0% |
| 384 | 1.8.11 | PRUEBA DE HUMEDAD |  | 2d | 2015-10-20 | 2015-10-21 | 383 | 32d | 2d | CALENDARIO DE TRABAJO MONTERESERVA | 0% | 0% |
| 385 | 1.5.4.15 | MUEBLE SALA Y CLÓSETS |  | 12d | 2015-10-09 | 2015-10-23 | 380 | 30d | 0d | CALENDARIO DE TRABAJO MONTERESERVA | 0% | 0% |
| 386 | 1.5.4.16 | MARCOS Y PUERTAS |  | 10d | 2015-10-09 | 2015-10-21 | 380 | 10d | 0d | CALENDARIO DE TRABAJO MONTERESERVA | 0% | 0% |
| 387 | 1.5.4.17 | CARPINTERÍA COCINA Y BAÑOS |  | 10d | 2015-10-09 | 2015-10-21 | 380 | 0d |  | CALENDARIO DE TRABAJO MONTERESERVA | 0% | 0% |
| 388 | 1.5.4.26 | PISO EN MADERA |  | 6d | 2015-10-24 | 2015-10-30 | 385, 386, 387, 384 | 30d | 2d | CALENDARIO DE TRABAJO MONTERESERVA | 0% | 0% |
| 389 | 1.5.4.18 | MARMOL DUCHAS, MESÓN MARMOL Y MUEBLES COCINAS |  | 10d | 2015-10-22 | 2015-11-03 | 387 | 0d |  | CALENDARIO DE TRABAJO MONTERESERVA | 0% | 0% |
| 390 | 1.5.7.24 | GASODOMÉSTICOS |  | 2d | 2015-11-04 | 2015-11-05 | 389 | 1d |  | CALENDARIO DE TRABAJO MONTERESERVA | 0% | 0% |
| 391 | 1.8.18 | ESPEJOS BAÑOS |  | 3d | 2015-11-04 | 2015-11-06 | 389 | 0d |  | CALENDARIO DE TRABAJO MONTERESERVA | 0% | 0% |
| 392 | 1.5.4.25 | ASEO |  | 2d | 2015-11-07 | 2015-11-09 | 391 | 59d | 0d | CALENDARIO DE TRABAJO MONTERESERVA | 0% | 0% |
| 393 | 1.8.20 | INSTALACION GUARDAESCOBA |  | 4d | 2015-11-10 | 2015-11-13 | 392 | 59d |  | CALENDARIO DE TRABAJO MONTERESERVA | 0% | 0% |
| 394 | 1.8.21 | APARATOS ELECRICOS |  | 2d | 2015-11-04 | 2015-11-05 | 389 | 1d |  | CALENDARIO DE TRABAJO MONTERESERVA | 0% | 0% |
| 395 | 1.5.4.22 | PINTURA 3 |  | 8d | 2015-11-07 | 2015-11-17 | 390, 391, 394 | 0d |  | CALENDARIO DE TRABAJO MONTERESERVA | 0% | 0% |
| 396 | 1.5.4.27 | ALFOMBRA |  | 2d | 2015-11-18 | 2015-11-19 | 395 | 49d | 0d | CALENDARIO DE TRABAJO MONTERESERVA | 0% | 0% |
| 397 | 1.5.4.28 | REVISIÓN FINAL Y ENTREGA |  | 6d | 2015-11-20 | 2015-11-26 | 396 | 49d | 31d | CALENDARIO DE TRABAJO MONTERESERVA | 0% | 0% |

| ID | WBS | Task | Duration | Start | Finish | Predecessors | Total slack | Free slack | Calendar | Text1 | Text2 |
| --- | --- | --- | --- | --- | --- | --- | --- | --- | --- | --- | --- |
| 398 | 1.5.7 | **ACABADOS 201** | 65d | 2015-09-07 | 2015-12-05 |  | 5d |  | DIAS CALENDARIO 2 | 0% | 0% |
| 399 | 1.5.7.1 | ESTUCO Y PINTURA 1 | 6d | 2015-09-14 | 2015-09-19 | 374 | 4d | 0d | CALENDARIO DE TRABAJO MONTERESERVA | 0% | 0% |
| 400 | 1.5.7.3 | ENCHAPES BAÑOS Y COCINAS | 6d | 2015-09-21 | 2015-09-26 | 399 | 98d |  | CALENDARIO DE TRABAJO MONTERESERVA | 0% | 0% |
| 401 | 1.5.7.8 | ESTRUCTURA CIELO RASO | 6d | 2015-09-07 | 2015-09-14 | 399SF | 6d | 2d | CALENDARIO DE TRABAJO MONTERESERVA | 0% | 0% |
| 402 | 1.5.7.9 | EMPLACADO C.R | 6d | 2015-09-16 | 2015-09-22 | 401, 377 | 4d | 0d | CALENDARIO DE TRABAJO MONTERESERVA | 0% | 0% |
| 403 | 1.5.7.10 | MASILLA C.R | 6d | 2015-09-23 | 2015-09-29 | 402 | 4d | 0d | CALENDARIO DE TRABAJO MONTERESERVA | 0% | 0% |
| 404 | 1.5.7.11 | PINTURA C.R | 6d | 2015-09-30 | 2015-10-06 | 403 | 4d | 2d | CALENDARIO DE TRABAJO MONTERESERVA | 0% | 0% |
| 405 | 1.5.7.12 | PINTURA 2 | 8d | 2015-10-09 | 2015-10-19 | 404, 380, 402, 187, 399 | 2d | 0d | CALENDARIO DE TRABAJO MONTERESERVA | 0% | 0% |
| 406 | 1.5.7.23 | APARATOS SANITARIOS | 3d | 2015-10-20 | 2015-10-22 | 405 | 30d | 0d | CALENDARIO DE TRABAJO MONTERESERVA | 0% | 0% |
| 407 | 1.9.9 | DIVISIONES DE DUCHAS | 3d | 2015-10-23 | 2015-10-26 | 406 | 30d | 0d | CALENDARIO DE TRABAJO MONTERESERVA | 0% | 0% |
| 408 | 1.9.10 | ASEO PARA INSTALACION PISO | 2d | 2015-10-27 | 2015-10-28 | 407 | 30d | 0d | CALENDARIO DE TRABAJO MONTERESERVA | 0% | 0% |
| 409 | 1.9.11 | PRUEBA DE HUMEDAD | 2d | 2015-10-29 | 2015-10-30 | 408 | 30d | 2d | CALENDARIO DE TRABAJO MONTERESERVA | 0% | 0% |
| 410 | 1.5.4.15 | MUEBLE SALA Y CLÓSETS | 12d | 2015-10-20 | 2015-11-03 | 405 | 28d | 0d | CALENDARIO DE TRABAJO MONTERESERVA | 0% | 0% |
| 411 | 1.5.4.16 | MARCOS Y PUERTAS | 10d | 2015-10-22 | 2015-11-03 | 405, 386 | 10d | 0d | CALENDARIO DE TRABAJO MONTERESERVA | 0% | 0% |
| 412 | 1.5.4.17 | CARPINTERÍA COCINA Y BAÑOS | 8d | 2015-10-22 | 2015-10-30 | 405, 387 | 0d |  | CALENDARIO DE TRABAJO MONTERESERVA | 0% | 0% |
| 413 | 1.5.4.26 | PISO EN MADERA | 6d | 2015-11-04 | 2015-11-10 | 409, 410, 411, 412, 388 | 28d | 4d | CALENDARIO DE TRABAJO MONTERESERVA | 0% | 0% |
| 414 | 1.5.4.18 | MARMOL DUCHAS, MESÓN MARMOL Y MUEBLES COCINAS | 10d | 2015-10-31 | 2015-11-12 | 412 | 0d |  | CALENDARIO DE TRABAJO MONTERESERVA | 0% | 0% |
| 415 | 1.5.7.24 | GASODOMÉSTICOS | 2d | 2015-11-13 | 2015-11-14 | 414 | 1d | 2d | CALENDARIO DE TRABAJO MONTERESERVA | 0% | 0% |
| 416 | 1.9.18 | ESPEJOS BAÑOS | 3d | 2015-11-13 | 2015-11-17 | 414 | 0d |  | CALENDARIO DE TRABAJO MONTERESERVA | 0% | 0% |
| 417 | 1.5.4.25 | ASEO | 2d | 2015-11-18 | 2015-11-19 | 416 | 51d | 0d | CALENDARIO DE TRABAJO MONTERESERVA | 0% | 0% |
| 418 | 1.9.20 | INSTALACION GUARDAESCOBA | 4d | 2015-11-20 | 2015-11-24 | 417 | 51d |  | CALENDARIO DE TRABAJO MONTERESERVA | 0% | 0% |
| 419 | 1.9.21 | APARATOS ELECRICOS | 2d | 2015-11-13 | 2015-11-14 | 414 | 1d | 2d | CALENDARIO DE TRABAJO MONTERESERVA | 0% | 0% |
| 420 | 1.5.4.22 | PINTURA 3 | 8d | 2015-11-18 | 2015-11-26 | 415, 416, 419, 395 | 0d |  | CALENDARIO DE TRABAJO MONTERESERVA | 0% | 0% |
| 421 | 1.5.4.27 | ALFOMBRA | 2d | 2015-11-27 | 2015-11-28 | 420 | 41d | 0d | CALENDARIO DE TRABAJO MONTERESERVA | 0% | 0% |
| 422 | 1.5.4.28 | REVISIÓN FINAL Y ENTREGA | 6d | 2015-11-30 | 2015-12-05 | 421 | 41d |  | CALENDARIO DE TRABAJO MONTERESERVA | 0% | 0% |

| ID | WBS | Task | Duration | Start | Finish | Predecessors | Total slack | Free slack | Calendar | Text1 | Text2 |
| --- | --- | --- | --- | --- | --- | --- | --- | --- | --- | --- | --- |
| 423 | 1.5.7 | **ACABADOS 301** | 68d | 2015-09-14 | 2015-12-16 |  | 5d |  | DIAS CALENDARIO 2 | 0% | 0% |
| 424 | 1.5.7.1 | ESTUCO Y PINTURA 1 | 6d | 2015-09-21 | 2015-09-26 | 399 | 4d | 0d | CALENDARIO DE TRABAJO MONTERESERVA | 0% | 0% |
| 425 | 1.5.7.3 | ENCHAPES BAÑOS Y COCINAS | 6d | 2015-09-28 | 2015-10-03 | 424 | 92d |  | CALENDARIO DE TRABAJO MONTERESERVA | 0% | 0% |
| 426 | 1.10.3 | ACABADOS CHIMENEA | 6d | 2015-09-14 | 2015-09-21 | 424SF | 26d | 21d | CALENDARIO DE TRABAJO MONTERESERVA |  |  |
| 427 | 1.5.7.8 | ESTRUCTURA CIELO RASO | 6d | 2015-09-14 | 2015-09-21 | 424SF | 6d | 2d | CALENDARIO DE TRABAJO MONTERESERVA | 0% | 0% |
| 428 | 1.5.7.9 | EMPLACADO C.R | 6d | 2015-09-23 | 2015-09-29 | 427, 402 | 4d | 0d | CALENDARIO DE TRABAJO MONTERESERVA | 0% | 0% |
| 429 | 1.5.7.10 | MASILLA C.R | 6d | 2015-09-30 | 2015-10-06 | 428 | 6d | 0d | CALENDARIO DE TRABAJO MONTERESERVA | 0% | 0% |
| 430 | 1.5.7.11 | PINTURA C.R | 6d | 2015-10-07 | 2015-10-14 | 429 | 6d | 3d | CALENDARIO DE TRABAJO MONTERESERVA | 0% | 0% |
| 431 | 1.5.7.12 | PINTURA 2 | 8d | 2015-10-20 | 2015-10-28 | 430, 405, 426, 428, 188, 424 | 2d | 0d | CALENDARIO DE TRABAJO MONTERESERVA | 0% | 0% |
| 432 | 1.5.7.23 | APARATOS SANITARIOS | 3d | 2015-10-29 | 2015-10-31 | 431 | 28d | 1d | CALENDARIO DE TRABAJO MONTERESERVA | 0% | 0% |
| 433 | 1.10.10 | DIVISIONES DE DUCHAS | 3d | 2015-11-03 | 2015-11-05 | 432 | 28d | 0d | CALENDARIO DE TRABAJO MONTERESERVA | 0% | 0% |
| 434 | 1.10.11 | ASEO PARA INSTALACION PISO | 2d | 2015-11-06 | 2015-11-07 | 433 | 28d | 0d | CALENDARIO DE TRABAJO MONTERESERVA | 0% | 0% |
| 435 | 1.10.12 | PRUEBA DE HUMEDAD | 2d | 2015-11-09 | 2015-11-10 | 434 | 28d | 4d | CALENDARIO DE TRABAJO MONTERESERVA | 0% | 0% |
| 436 | 1.5.4.15 | MUEBLE SALA Y CLÓSETS | 12d | 2015-10-29 | 2015-11-12 | 431 | 26d | 2d | CALENDARIO DE TRABAJO MONTERESERVA | 0% | 0% |
| 437 | 1.5.4.16 | MARCOS Y PUERTAS | 10d | 2015-11-04 | 2015-11-14 | 431, 411 | 10d | 1d | CALENDARIO DE TRABAJO MONTERESERVA | 0% | 0% |
| 438 | 1.5.4.17 | CARPINTERÍA COCINA Y BAÑOS | 8d | 2015-10-31 | 2015-11-10 | 431, 412 | 0d |  | CALENDARIO DE TRABAJO MONTERESERVA | 0% | 0% |
| 439 | 1.5.4.26 | PISO EN MADERA | 6d | 2015-11-17 | 2015-11-23 | 435, 436, 437, 438, 413 | 24d | 4d | CALENDARIO DE TRABAJO MONTERESERVA | 0% | 0% |
| 440 | 1.5.4.18 | MARMOL DUCHAS, MESÓN MARMOL Y MUEBLES COCINAS | 10d | 2015-11-11 | 2015-11-23 | 438 | 0d |  | CALENDARIO DE TRABAJO MONTERESERVA | 0% | 0% |
| 441 | 1.5.7.24 | GASODOMÉSTICOS | 2d | 2015-11-24 | 2015-11-25 | 440 | 1d |  | CALENDARIO DE TRABAJO MONTERESERVA | 0% | 0% |
| 442 | 1.10.19 | ESPEJOS BAÑOS | 3d | 2015-11-24 | 2015-11-26 | 440 | 0d |  | CALENDARIO DE TRABAJO MONTERESERVA | 0% | 0% |
| 443 | 1.5.4.25 | ASEO | 2d | 2015-11-27 | 2015-11-28 | 442 | 43d | 0d | CALENDARIO DE TRABAJO MONTERESERVA | 0% | 0% |
| 444 | 1.10.21 | INSTALACION GUARDAESCOBA | 4d | 2015-11-30 | 2015-12-03 | 443 | 43d |  | CALENDARIO DE TRABAJO MONTERESERVA | 0% | 0% |
| 445 | 1.10.22 | APARATOS ELECRICOS | 2d | 2015-11-24 | 2015-11-25 | 440 | 1d |  | CALENDARIO DE TRABAJO MONTERESERVA | 0% | 0% |
| 446 | 1.5.4.22 | PINTURA 3 | 8d | 2015-11-27 | 2015-12-05 | 441, 442, 445, 420 | 0d |  | CALENDARIO DE TRABAJO MONTERESERVA | 0% | 0% |
| 447 | 1.5.4.27 | ALFOMBRA | 2d | 2015-12-07 | 2015-12-09 | 446 | 33d | 0d | CALENDARIO DE TRABAJO MONTERESERVA | 0% | 0% |
| 448 | 1.5.4.28 | REVISIÓN FINAL Y ENTREGA | 6d | 2015-12-10 | 2015-12-16 | 447 | 33d |  | CALENDARIO DE TRABAJO MONTERESERVA | 0% | 0% |

| ID | WBS | Task | Duration | Start | Finish | Predecessors | Total slack | Free slack | Calendar | Text1 | Text2 |
| --- | --- | --- | --- | --- | --- | --- | --- | --- | --- | --- | --- |
| 449 | 1.5.7 | **ACABADOS 401** | 80d | 2015-09-21 | 2016-01-08 |  | 5d |  | DIAS CALENDARIO 2 | 0% | 0% |
| 450 | 1.5.7.1 | ESTUCO Y PINTURA 1 | 6d | 2015-09-28 | 2015-10-03 | 424 | 4d | 0d | CALENDARIO DE TRABAJO MONTERESERVA | 0% | 0% |
| 451 | 1.5.7.3 | ENCHAPES BAÑOS Y COCINAS | 6d | 2015-10-05 | 2015-10-10 | 450 | 86d |  | CALENDARIO DE TRABAJO MONTERESERVA | 0% | 0% |
| 452 | 1.11.3 | ACABADOS CHIMENEA | 6d | 2015-09-21 | 2015-09-28 | 450SF | 28d | 23d | CALENDARIO DE TRABAJO MONTERESERVA |  |  |
| 453 | 1.5.7.8 | ESTRUCTURA CIELO RASO | 6d | 2015-09-21 | 2015-09-28 | 450SF | 6d | 2d | CALENDARIO DE TRABAJO MONTERESERVA | 0% | 0% |
| 454 | 1.5.7.9 | EMPLACADO C.R | 6d | 2015-09-30 | 2015-10-06 | 453, 428 | 4d | 0d | CALENDARIO DE TRABAJO MONTERESERVA | 0% | 0% |
| 455 | 1.5.7.10 | MASILLA C.R | 6d | 2015-10-07 | 2015-10-14 | 454 | 8d | 0d | CALENDARIO DE TRABAJO MONTERESERVA | 0% | 0% |
| 456 | 1.5.7.11 | PINTURA C.R | 6d | 2015-10-15 | 2015-10-21 | 455 | 8d | 5d | CALENDARIO DE TRABAJO MONTERESERVA | 0% | 0% |
| 457 | 1.5.7.12 | PINTURA 2 | 8d | 2015-10-29 | 2015-11-07 | 452, 456, 431, 454, 189, 450 | 2d | 0d | CALENDARIO DE TRABAJO MONTERESERVA | 0% | 0% |
| 458 | 1.5.7.23 | APARATOS SANITARIOS | 3d | 2015-11-09 | 2015-11-11 | 457 | 26d | 0d | CALENDARIO DE TRABAJO MONTERESERVA | 0% | 0% |
| 459 | 1.11.10 | DIVISIONES DE DUCHAS | 3d | 2015-11-12 | 2015-11-14 | 458 | 26d | 1d | CALENDARIO DE TRABAJO MONTERESERVA | 0% | 0% |
| 460 | 1.11.11 | ASEO PARA INSTALACION PISO | 2d | 2015-11-17 | 2015-11-18 | 459 | 26d | 0d | CALENDARIO DE TRABAJO MONTERESERVA | 0% | 0% |
| 461 | 1.11.12 | PRUEBA DE HUMEDAD | 2d | 2015-11-19 | 2015-11-20 | 460 | 26d | 5d | CALENDARIO DE TRABAJO MONTERESERVA | 0% | 0% |
| 462 | 1.5.4.15 | MUEBLE SALA Y CLÓSETS | 12d | 2015-11-09 | 2015-11-23 | 457 | 24d | 4d | CALENDARIO DE TRABAJO MONTERESERVA | 0% | 0% |
| 463 | 1.5.4.16 | MARCOS Y PUERTAS | 10d | 2015-11-17 | 2015-11-27 | 457, 437 | 10d | 0d | CALENDARIO DE TRABAJO MONTERESERVA | 0% | 0% |
| 464 | 1.5.4.17 | CARPINTERÍA COCINA Y BAÑOS | 8d | 2015-11-11 | 2015-11-20 | 457, 438 | 0d |  | CALENDARIO DE TRABAJO MONTERESERVA | 0% | 0% |
| 465 | 1.5.4.26 | PISO EN MADERA | 6d | 2015-11-28 | 2015-12-04 | 461, 462, 463, 464, 439 | 20d | 4d | CALENDARIO DE TRABAJO MONTERESERVA | 0% | 0% |
| 466 | 1.5.4.18 | MARMOL DUCHAS, MESÓN MARMOL Y MUEBLES COCINAS | 10d | 2015-11-21 | 2015-12-02 | 464 | 0d |  | CALENDARIO DE TRABAJO MONTERESERVA | 0% | 0% |
| 467 | 1.5.7.24 | GASODOMÉSTICOS | 2d | 2015-12-03 | 2015-12-04 | 466 | 1d | 0d | CALENDARIO DE TRABAJO MONTERESERVA | 0% | 0% |
| 468 | 1.11.19 | ESPEJOS BAÑOS | 3d | 2015-12-03 | 2015-12-05 | 466 | 0d |  | CALENDARIO DE TRABAJO MONTERESERVA | 0% | 0% |
| 469 | 1.5.4.25 | ASEO | 2d | 2015-12-07 | 2015-12-09 | 468 | 35d | 0d | CALENDARIO DE TRABAJO MONTERESERVA | 0% | 0% |
| 470 | 1.11.21 | INSTALACION GUARDAESCOBA | 4d | 2015-12-10 | 2015-12-14 | 469 | 35d |  | CALENDARIO DE TRABAJO MONTERESERVA | 0% | 0% |
| 471 | 1.11.22 | APARATOS ELECRICOS | 2d | 2015-12-03 | 2015-12-04 | 466 | 1d | 0d | CALENDARIO DE TRABAJO MONTERESERVA | 0% | 0% |
| 472 | 1.5.4.22 | PINTURA 3 | 8d | 2015-12-07 | 2015-12-16 | 467, 468, 471, 446 | 0d |  | CALENDARIO DE TRABAJO MONTERESERVA | 0% | 0% |
| 473 | 1.5.4.27 | ALFOMBRA | 2d | 2015-12-17 | 2015-12-18 | 472 | 4d |  | CALENDARIO DE TRABAJO MONTERESERVA | 0% | 0% |
| 474 | 1.5.4.28 | REVISIÓN FINAL Y ENTREGA | 6d | 2015-12-19 | 2016-01-08 | 473 | 4d | 0d | CALENDARIO DE TRABAJO MONTERESERVA | 0% | 0% |

| ID | WBS | Task | Duration | Start | Finish | Predecessors | Total slack | Free slack | Calendar | Text1 | Text2 |
| --- | --- | --- | --- | --- | --- | --- | --- | --- | --- | --- | --- |
| 475 | 1.5.7 | **ACABADOS 501** | 82d | 2015-09-28 | 2016-01-19 |  | 5d |  | DIAS CALENDARIO 2 | 0% | 0% |
| 476 | 1.5.7.1 | ESTUCO Y PINTURA 1 | 6d | 2015-10-05 | 2015-10-10 | 450 | 4d | 0d | CALENDARIO DE TRABAJO MONTERESERVA | 0% | 0% |
| 477 | 1.5.7.3 | ENCHAPES BAÑOS Y COCINAS | 6d | 2015-10-13 | 2015-10-19 | 476 | 80d |  | CALENDARIO DE TRABAJO MONTERESERVA | 0% | 0% |
| 478 | 1.12.3 | ACABADOS CHIMENEA | 6d | 2015-09-28 | 2015-10-05 | 476SF | 30d | 25d | CALENDARIO DE TRABAJO MONTERESERVA |  |  |
| 479 | 1.5.7.8 | ESTRUCTURA CIELO RASO | 6d | 2015-09-28 | 2015-10-05 | 476SF | 6d | 2d | CALENDARIO DE TRABAJO MONTERESERVA | 0% | 0% |
| 480 | 1.5.7.9 | EMPLACADO C.R | 6d | 2015-10-07 | 2015-10-14 | 479, 454 | 4d | 0d | CALENDARIO DE TRABAJO MONTERESERVA | 0% | 0% |
| 481 | 1.5.7.10 | MASILLA C.R | 6d | 2015-10-15 | 2015-10-21 | 480 | 10d | 0d | CALENDARIO DE TRABAJO MONTERESERVA | 0% | 0% |
| 482 | 1.5.7.11 | PINTURA C.R | 6d | 2015-10-22 | 2015-10-28 | 481 | 10d | 7d | CALENDARIO DE TRABAJO MONTERESERVA | 0% | 0% |
| 483 | 1.5.7.12 | PINTURA 2 | 8d | 2015-11-09 | 2015-11-18 | 478, 482, 457, 480, 190, 476 | 2d | 0d | CALENDARIO DE TRABAJO MONTERESERVA | 0% | 0% |
| 484 | 1.5.7.23 | APARATOS SANITARIOS | 3d | 2015-11-19 | 2015-11-21 | 483 | 24d | 0d | CALENDARIO DE TRABAJO MONTERESERVA | 0% | 0% |
| 485 | 1.12.10 | DIVISIONES DE DUCHAS | 3d | 2015-11-23 | 2015-11-25 | 484 | 24d | 0d | CALENDARIO DE TRABAJO MONTERESERVA | 0% | 0% |
| 486 | 1.12.11 | ASEO PARA INSTALACION PISO | 2d | 2015-11-26 | 2015-11-27 | 485 | 24d | 0d | CALENDARIO DE TRABAJO MONTERESERVA | 0% | 0% |
| 487 | 1.12.12 | PRUEBA DE HUMEDAD | 2d | 2015-11-28 | 2015-11-30 | 486 | 24d | 8d | CALENDARIO DE TRABAJO MONTERESERVA | 0% | 0% |
| 488 | 1.5.4.15 | MUEBLE SALA Y CLÓSETS | 12d | 2015-11-19 | 2015-12-02 | 483 | 22d | 6d | CALENDARIO DE TRABAJO MONTERESERVA | 0% | 0% |
| 489 | 1.5.4.16 | MARCOS Y PUERTAS | 10d | 2015-11-28 | 2015-12-10 | 483, 463 | 10d | 0d | CALENDARIO DE TRABAJO MONTERESERVA | 0% | 0% |
| 490 | 1.5.4.17 | CARPINTERÍA COCINA Y BAÑOS | 8d | 2015-11-21 | 2015-11-30 | 483, 464 | 0d |  | CALENDARIO DE TRABAJO MONTERESERVA | 0% | 0% |
| 491 | 1.5.4.26 | PISO EN MADERA | 6d | 2015-12-11 | 2015-12-17 | 487, 488, 489, 490, 465 | 16d | 13d | CALENDARIO DE TRABAJO MONTERESERVA | 0% | 0% |
| 492 | 1.5.4.18 | MARMOL DUCHAS, MESÓN MARMOL Y MUEBLES COCINAS | 10d | 2015-12-01 | 2015-12-12 | 490 | 0d |  | CALENDARIO DE TRABAJO MONTERESERVA | 0% | 0% |
| 493 | 1.5.7.24 | GASODOMÉSTICOS | 2d | 2015-12-14 | 2015-12-15 | 492 | 1d |  | CALENDARIO DE TRABAJO MONTERESERVA | 0% | 0% |
| 494 | 1.12.19 | ESPEJOS BAÑOS | 3d | 2015-12-14 | 2015-12-16 | 492 | 0d |  | CALENDARIO DE TRABAJO MONTERESERVA | 0% | 0% |
| 495 | 1.5.4.25 | ASEO | 2d | 2015-12-17 | 2015-12-18 | 494 | 27d | 0d | CALENDARIO DE TRABAJO MONTERESERVA | 0% | 0% |
| 496 | 1.12.21 | INSTALACION GUARDAESCOBA | 4d | 2015-12-19 | 2016-01-06 | 495 | 27d |  | CALENDARIO DE TRABAJO MONTERESERVA | 0% | 0% |
| 497 | 1.12.22 | APARATOS ELECRICOS | 2d | 2015-12-14 | 2015-12-15 | 492 | 1d |  | CALENDARIO DE TRABAJO MONTERESERVA | 0% | 0% |
| 498 | 1.5.4.22 | PINTURA 3 | 8d | 2015-12-17 | 2016-01-08 | 493, 494, 497, 472 | 0d |  | CALENDARIO DE TRABAJO MONTERESERVA | 0% | 0% |
| 499 | 1.5.4.27 | ALFOMBRA | 2d | 2016-01-09 | 2016-01-12 | 498 | 17d | 0d | CALENDARIO DE TRABAJO MONTERESERVA | 0% | 0% |
| 500 | 1.5.4.28 | REVISIÓN FINAL Y ENTREGA | 6d | 2016-01-13 | 2016-01-19 | 499 | 17d | 0d | CALENDARIO DE TRABAJO MONTERESERVA | 0% | 0% |

| ID | WBS | Task | Duration | Start | Finish | Predecessors | Total slack | Free slack | Calendar | Text1 | Text2 |
| --- | --- | --- | --- | --- | --- | --- | --- | --- | --- | --- | --- |
| 501 | 1.5.7 | **ACABADOS 601( BAJILLO )** | 88d | 2015-09-30 | 2016-01-29 |  | 5d |  | DIAS CALENDARIO 2 | 0% | 0% |
| 502 | 1.5.7.1 | ESTUCO Y PINTURA 1 | 10d | 2015-10-13 | 2015-10-23 | 476 | 4d | 0d | CALENDARIO DE TRABAJO MONTERESERVA | 0% | 0% |
| 503 | 1.5.7.3 | ENCHAPES BAÑOS Y COCINAS | 6d | 2015-10-24 | 2015-10-30 | 502 | 70d |  | CALENDARIO DE TRABAJO MONTERESERVA | 0% | 0% |
| 504 | 1.13.3 | ACABADOS CHIMENEA | 6d | 2015-10-05 | 2015-10-13 | 502SF | 32d | 27d | CALENDARIO DE TRABAJO MONTERESERVA |  |  |
| 505 | 1.5.7.8 | ESTRUCTURA CIELO RASO | 10d | 2015-09-30 | 2015-10-13 | 502SF | 6d | 2d | CALENDARIO DE TRABAJO MONTERESERVA | 0% | 0% |
| 506 | 1.5.7.9 | EMPLACADO C.R | 8d | 2015-10-15 | 2015-10-23 | 505, 480 | 4d | 0d | CALENDARIO DE TRABAJO MONTERESERVA | 0% | 0% |
| 507 | 1.5.7.10 | MASILLA C.R | 10d | 2015-10-24 | 2015-11-05 | 506 | 4d | 0d | CALENDARIO DE TRABAJO MONTERESERVA | 0% | 0% |
| 508 | 1.5.7.11 | PINTURA C.R | 8d | 2015-11-06 | 2015-11-14 | 507 | 4d | 3d | CALENDARIO DE TRABAJO MONTERESERVA | 0% | 0% |
| 509 | 1.5.7.12 | PINTURA 2 | 9d | 2015-11-19 | 2015-11-28 | 504, 508, 483, 506, 191, 502 | 2d | 0d | CALENDARIO DE TRABAJO MONTERESERVA | 0% | 0% |
| 510 | 1.5.7.23 | APARATOS SANITARIOS | 3d | 2015-11-30 | 2015-12-02 | 509 | 21d | 0d | CALENDARIO DE TRABAJO MONTERESERVA | 0% | 0% |
| 511 | 1.13.10 | DIVISIONES DE DUCHAS | 3d | 2015-12-03 | 2015-12-05 | 510 | 21d | 0d | CALENDARIO DE TRABAJO MONTERESERVA | 0% | 0% |
| 512 | 1.13.11 | ASEO PARA INSTALACION PISO | 2d | 2015-12-07 | 2015-12-09 | 511 | 21d | 0d | CALENDARIO DE TRABAJO MONTERESERVA | 0% | 0% |
| 513 | 1.13.12 | PRUEBA DE HUMEDAD | 2d | 2015-12-10 | 2015-12-11 | 512 | 21d | 17d | CALENDARIO DE TRABAJO MONTERESERVA | 0% | 0% |
| 514 | 1.5.4.15 | MUEBLE SALA Y CLÓSETS | 12d | 2015-11-30 | 2015-12-14 | 509 | 19d | 16d | CALENDARIO DE TRABAJO MONTERESERVA | 0% | 0% |
| 515 | 1.5.4.16 | MARCOS Y PUERTAS | 10d | 2015-12-11 | 2016-01-05 | 509, 489 | 10d | 0d | CALENDARIO DE TRABAJO MONTERESERVA | 0% | 0% |
| 516 | 1.5.4.17 | CARPINTERÍA COCINA Y BAÑOS | 8d | 2015-12-01 | 2015-12-10 | 509, 490 | 1d | 0d | CALENDARIO DE TRABAJO MONTERESERVA | 0% | 0% |
| 517 | 1.5.4.26 | PISO EN MADERA | 8d | 2016-01-06 | 2016-01-15 | 513, 514, 515, 516, 491 | 12d | 1d | CALENDARIO DE TRABAJO MONTERESERVA | 0% | 0% |
| 518 | 1.5.4.18 | MARMOL DUCHAS, MESÓN MARMOL Y MUEBLES COCINAS | 10d | 2015-12-11 | 2016-01-05 | 516 | 1d | 0d | CALENDARIO DE TRABAJO MONTERESERVA | 0% | 0% |
| 519 | 1.5.7.24 | GASODOMÉSTICOS | 2d | 2016-01-06 | 2016-01-07 | 518 | 1d |  | CALENDARIO DE TRABAJO MONTERESERVA | 0% | 0% |
| 520 | 1.13.19 | ESPEJOS BAÑOS | 2d | 2016-01-06 | 2016-01-07 | 518 | 1d | 0d | CALENDARIO DE TRABAJO MONTERESERVA | 0% | 0% |
| 521 | 1.5.4.25 | ASEO | 2d | 2016-01-08 | 2016-01-09 | 520 | 19d | 1d | CALENDARIO DE TRABAJO MONTERESERVA | 0% | 0% |
| 522 | 1.13.21 | INSTALACION GUARDAESCOBA | 5d | 2016-01-12 | 2016-01-16 | 521 | 19d |  | CALENDARIO DE TRABAJO MONTERESERVA | 0% | 0% |
| 523 | 1.13.22 | APARATOS ELECRICOS | 2d | 2016-01-06 | 2016-01-07 | 518 | 1d |  | CALENDARIO DE TRABAJO MONTERESERVA | 0% | 0% |
| 524 | 1.5.4.22 | PINTURA 3 | 8d | 2016-01-09 | 2016-01-19 | 519, 520, 523, 498 | 0d |  | CALENDARIO DE TRABAJO MONTERESERVA | 0% | 0% |
| 525 | 1.5.4.27 | ALFOMBRA | 3d | 2016-01-20 | 2016-01-22 | 524 | 8d | 0d | CALENDARIO DE TRABAJO MONTERESERVA | 0% | 0% |
| 526 | 1.5.4.28 | REVISIÓN FINAL Y ENTREGA | 6d | 2016-01-23 | 2016-01-29 | 525 | 8d |  | CALENDARIO DE TRABAJO MONTERESERVA | 0% | 0% |

| ID | WBS | Task | Duration | Start | Finish | Predecessors | Total slack | Free slack | Calendar | Text1 | Text2 |
| --- | --- | --- | --- | --- | --- | --- | --- | --- | --- | --- | --- |
| 527 | 1.5.7 | **ACABADOS 601 ( ALTILLO )** | 81d | 2015-10-17 | 2016-02-08 |  | 0d |  | DIAS CALENDARIO 2 | 0% | 0% |
| 528 | 1.5.7.1 | ESTUCO Y PINTURA 1 | 10d | 2015-10-24 | 2015-11-05 | 502 | 4d | 0d | CALENDARIO DE TRABAJO MONTERESERVA | 0% | 0% |
| 529 | 1.5.7.3 | ENCHAPES BAÑOS Y COCINAS | 6d | 2015-11-06 | 2015-11-12 | 528 | 60d |  | CALENDARIO DE TRABAJO MONTERESERVA | 0% | 0% |
| 530 | 1.14.3 | ACABADOS CHIMENEA | 6d | 2015-10-17 | 2015-10-24 | 528SF | 32d | 25d | CALENDARIO DE TRABAJO MONTERESERVA |  |  |
| 531 | 1.5.7.8 | ESTRUCTURA CIELO RASO | 6d | 2015-10-17 | 2015-10-24 | 528SF | 4d | 0d | CALENDARIO DE TRABAJO MONTERESERVA | 0% | 0% |
| 532 | 1.5.7.9 | EMPLACADO C.R | 10d | 2015-10-24 | 2015-11-05 | 531, 506 | 4d | 0d | CALENDARIO DE TRABAJO MONTERESERVA | 0% | 0% |
| 533 | 1.5.7.10 | MASILLA C.R | 10d | 2015-11-06 | 2015-11-18 | 532 | 4d | 0d | CALENDARIO DE TRABAJO MONTERESERVA | 0% | 0% |
| 534 | 1.5.7.11 | PINTURA C.R | 8d | 2015-11-19 | 2015-11-27 | 533 | 4d | 0d | CALENDARIO DE TRABAJO MONTERESERVA | 0% | 0% |
| 535 | 1.5.7.12 | PINTURA 2 | 9d | 2015-11-30 | 2015-12-10 | 530, 534, 532, 192, 528, 509 | 3d | 0d | CALENDARIO DE TRABAJO MONTERESERVA | 0% | 0% |
| 536 | 1.5.7.23 | APARATOS SANITARIOS | 3d | 2015-12-11 | 2015-12-14 | 535 | 20d | 0d | CALENDARIO DE TRABAJO MONTERESERVA | 0% | 0% |
| 537 | 1.14.10 | DIVISIONES DE DUCHAS | 3d | 2015-12-15 | 2015-12-17 | 536 | 20d | 0d | CALENDARIO DE TRABAJO MONTERESERVA | 0% | 0% |
| 538 | 1.14.11 | ASEO PARA INSTALACION PISO | 2d | 2015-12-18 | 2015-12-19 | 537 | 20d | 10d | CALENDARIO DE TRABAJO MONTERESERVA | 0% | 0% |
| 539 | 1.14.12 | PRUEBA DE HUMEDAD | 2d | 2016-01-04 | 2016-01-05 | 538 | 20d | 9d | CALENDARIO DE TRABAJO MONTERESERVA | 0% | 0% |
| 540 | 1.5.4.15 | MUEBLE SALA Y CLÓSETS | 12d | 2015-12-11 | 2016-01-07 | 535 | 18d | 7d | CALENDARIO DE TRABAJO MONTERESERVA | 0% | 0% |
| 541 | 1.5.4.16 | MARCOS Y PUERTAS | 10d | 2016-01-06 | 2016-01-18 | 535, 515 | 10d | 0d | CALENDARIO DE TRABAJO MONTERESERVA | 0% | 0% |
| 542 | 1.5.4.17 | CARPINTERÍA COCINA Y BAÑOS | 8d | 2015-12-11 | 2015-12-19 | 535, 516 | 3d | 10d | CALENDARIO DE TRABAJO MONTERESERVA | 0% | 0% |
| 543 | 1.5.4.26 | PISO EN MADERA | 8d | 2016-01-19 | 2016-01-27 | 539, 540, 541, 542, 517 | 10d |  | CALENDARIO DE TRABAJO MONTERESERVA | 0% | 0% |
| 544 | 1.5.4.18 | MARMOL DUCHAS, MESÓN MARMOL Y MUEBLES COCINAS | 8d | 2016-01-04 | 2016-01-13 | 542 | 3d | 0d | CALENDARIO DE TRABAJO MONTERESERVA | 0% | 0% |
| 545 | 1.5.7.24 | GASODOMÉSTICOS | 2d | 2016-01-14 | 2016-01-15 | 544 | 3d | 2d | CALENDARIO DE TRABAJO MONTERESERVA | 0% | 0% |
| 546 | 1.14.19 | ESPEJOS BAÑOS | 2d | 2016-01-14 | 2016-01-15 | 544 | 3d | 0d | CALENDARIO DE TRABAJO MONTERESERVA | 0% | 0% |
| 547 | 1.5.4.25 | ASEO | 2d | 2016-01-16 | 2016-01-18 | 546 | 13d | 0d | CALENDARIO DE TRABAJO MONTERESERVA | 0% | 0% |
| 548 | 1.14.21 | INSTALACION GUARDAESCOBA | 5d | 2016-01-19 | 2016-01-23 | 547 | 13d |  | CALENDARIO DE TRABAJO MONTERESERVA | 0% | 0% |
| 549 | 1.14.22 | APARATOS ELECRICOS | 2d | 2016-01-14 | 2016-01-15 | 544 | 3d | 2d | CALENDARIO DE TRABAJO MONTERESERVA | 0% | 0% |
| 550 | 1.5.4.22 | PINTURA 3 | 8d | 2016-01-20 | 2016-01-28 | 545, 546, 549, 524 | 0d |  | CALENDARIO DE TRABAJO MONTERESERVA | 0% | 0% |
| 551 | 1.5.4.27 | ALFOMBRA | 3d | 2016-01-29 | 2016-02-01 | 550 | 0d |  | CALENDARIO DE TRABAJO MONTERESERVA | 0% | 0% |
| 552 | 1.5.4.28 | REVISIÓN FINAL Y ENTREGA | 6d | 2016-02-02 | 2016-02-08 | 551 | 0d |  | CALENDARIO DE TRABAJO MONTERESERVA | 0% | 0% |
